# 3GPP_Release-2000

Schedule from MS Project, 1999-01-01 to 2018-04-16, A marks actual dates.

| ID | WBS | Task | Duration | Start | Finish | Complete | Baseline start | Baseline finish | Baseline duration | Constraint | Resources | Work | Actual work | Release | MCC resp | TSG stopped | Acronym | WI rapporteur name | WI rapporteur e-mail | Acronym_3GU_Export | Impacted TSs and TRs |
| --- | --- | --- | --- | --- | --- | --- | --- | --- | --- | --- | --- | --- | --- | --- | --- | --- | --- | --- | --- | --- | --- |
| 4783 | 109.4 | **Deleted - GERAN MS Conformance test for GERAN interface evolution** | 660d | 2001-06-11 A | 2003-12-19 A | 100% | 2001-06-11 | 2003-12-19 | 660d |  | GP | 10560h | 10560h | Rel-5 | Paolo | GP-17 |  |  |  |  |  |
| 4784 | 109.4.1 | Deleted - MS test for GERAN interface evolution | 660d | 2001-06-11 A | 2003-12-19 A | 100% | 2001-06-11 | 2003-12-19 | 660d | finish no earlier than 2003-12-19 | GP | 5280h | 5280h | Rel-5 | Paolo | GP-17 |  |  |  |  |  |
| 4785 | 109.5 | **GERAN BSS Conformance test for GERAN interface evolution** | 922d | 2000-06-08 A | 2003-12-19 A | 100% | 2000-06-08 | 2003-12-19 | 922d |  | GP | 14752h | 14752h | Rel-5 | Paolo |  |  |  |  |  |  |
| 4786 | 109.5.1 | Deleted - BSS test | 922d | 2000-06-08 A | 2003-12-19 A | 100% | 2000-06-08 | 2003-12-19 | 922d | finish no earlier than 2003-12-19 | GP | 7376h | 7376h | Rel-5 | Paolo | GP-17 |  |  |  |  |  |
| 4787 | 110 | **GERAN support for IMS** | 690d | 2000-05-01 A | 2002-12-20 A | 100% | 2000-05-01 | 2002-12-20 | 690d |  | GP | 83939.6h | 83939.6h | Rel-5 | Paolo |  | GERIMS | Nokia | Shkumbin Hamiti | GERIMS |  |
| 4788 | 110.1 | **GERAN Header adaptation** | 690d | 2000-05-01 A | 2002-12-20 A | 100% | 2000-05-01 | 2002-12-20 | 690d |  | GP; S2; RP | 40011.6h | 40011.6h | Rel-5 | Paolo |  | GERIMS-HEADAPT | Nokia | Shkumbin Hamiti | GERIMS-HEADAPT |  |
| 4789 | 110.1.1 | Definition of compression and removal modes for PDCP protocol | 29.15d | 2000-07-24 A | 2000-09-01 A | 100% | 2000-07-24 | 2000-09-01 | 29.15d | finish no earlier than 2000-09-01 | GP; S2; RP | 699.6h | 699.6h | Rel-5 | Paolo |  |  |  |  |  |  |
| 4790 | 110.1.2 | Conceptual description in stage 2 | 393d | 2000-05-01 A | 2001-10-31 A | 100% | 2000-05-01 | 2001-10-31 | 393d | finish no earlier than 2001-10-31 | GP; S2; RP | 9432h | 9432h | Rel-5 | Paolo |  |  |  |  |  |  |
| 4791 | 110.1.3 | Necessary changes on stage 3 regarding header removal | 555d | 2000-11-06 A | 2002-12-20 A | 100% | 2000-11-06 | 2002-12-20 | 555d | finish no earlier than 2002-12-20 | GP; S2; RP | 13320h | 13320h | Rel-5 | Paolo |  |  |  |  |  |  |
| 4792 | 110.2 | **Deleted - GERAN Radio access bearer design for IMS** | 430d | 2000-11-06 A | 2002-06-28 A | 100% | 2000-11-06 | 2002-06-28 | 430d |  | GP; S2; RP | 29520h | 29520h | Rel-5 | Paolo | GP-10 | GERIMS-RABDES | Nokia | Shkumbin Hamiti | GERIMS-RABDES |  |
| 4793 | 110.2.1 | **Deleted - MuM control signalling for conversational multimedia services** | 430d | 2000-11-06 A | 2002-06-28 A | 100% | 2000-11-06 | 2002-06-28 | 430d |  | GP; S2; RP | 19200h | 19200h | Rel-5 | Paolo | GP-10 |  |  |  |  |  |
| 4794 | 110.2.1.1 | Deleted - Identification of requirements for MuM control signalling for conversational multimedia services | 330d | 2000-11-06 A | 2002-02-08 A | 100% | 2000-11-06 | 2002-02-08 | 330d | finish no earlier than 2002-02-08 | GP; S2; RP | 7920h | 7920h | Rel-5 | Paolo | GP-08 |  |  |  |  |  |
| 4795 | 110.2.1.2 | Deleted - Necessary modifications due to SIP | 40d | 2002-05-06 A | 2002-06-28 A | 100% | 2002-05-06 | 2002-06-28 | 40d | finish no earlier than 2002-06-28 | GP; S2; RP | 960h | 960h | Rel-5 | Paolo | GP-10 |  |  |  |  |  |
| 4796 | 110.3 | **Deleted - GERAN MS Conformance test for support of IMS** | 400d | 2001-06-11 A | 2002-12-20 A | 100% | 2001-06-11 | 2002-12-20 | 400d |  | GP | 6400h | 6400h | Rel-5 | Paolo | GP-12 | GERIMS-MSconf | Nokia | Shkumbin Hamiti | GERIMS-MSconf |  |
| 4797 | 110.3.1 | Deleted - MS test for support of IMS | 400d | 2001-06-11 A | 2002-12-20 A | 100% | 2001-06-11 | 2002-12-20 | 400d | finish no earlier than 2002-12-20 | G4 | 3200h | 3200h | Rel-5 | Paolo | GP-12 |  |  |  |  |  |
| 4798 | 110.4 | Deleted - GERAN BTS Conformance test for support of IMS | 400d | 2001-06-11 A | 2002-12-20 A | 100% | 2001-06-11 | 2002-12-20 | 400d |  | GP | 3200h | 3200h | Rel-5 | Paolo | GP-12 | GERIMS-BTSconf | Nokia | Shkumbin Hamiti | GERIMS-BTSconf |  |
| 4799 | 1135 | MS Conformance Testing of Dual Transfer Mode | 65d? | 2002-11-11 A | 2003-02-07 A | 100% | 2002-11-11 | 2003-02-07 | 65d? | finish no earlier than 2003-02-07 | G4; G5 | 1040h | 1040h | Rel-5 | Paolo |  | MSCTDTM | Vodafone | Dave Fox | MSCTDTM |  |
| 4800 | 1136 | **Handling of early Ues** | 911d? | 2000-01-03 A | 2003-06-27 A | 100% | 2000-01-03 | 2003-06-27 | 911d? |  | S2 | 4488h | 4488h | Rel-5 | Maurice |  | LATE_UE |  |  | LATE_UE |  |
| 4801 | 1136.1 | Feasibility Study on Handling of early Ues | 50d? | 2002-10-07 A | 2002-12-13 A | 100% | 2002-10-07 | 2002-12-13 | 50d? | finish no earlier than 2002-12-13 | S2 | 400h | 400h | Rel-5 | Maurice |  |  |  |  |  |  |
| 4802 | 1136.2 | Stage 2 for Handling of early Ues | 125d? | 2003-01-06 A | 2003-06-27 A | 100% | 2003-01-06 | 2003-06-27 | 125d? | start no earlier than 2003-01-06 | S2 | 1000h | 1000h | Rel-5 | Maurice |  |  |  |  |  |  |
| 4803 | 1136.3 | FS for the Early Mobile Handling in UTRAN | 195d | 2002-09-09 A | 2003-06-06 A | 100% | 2002-09-09 | 2003-06-06 | 195d | finish no earlier than 2003-06-06 | R2 | 1560h | 1560h | Rel-5 | Yong-Jun |  | FSEarlyUE | Vodafone | alan.law@vodafone.com | FSEarlyUE |  |
| 4804 | 1136.4 | Note: Stage 3 RAN part not shown | 1d | 2000-01-03 A | 2000-01-03 A | 100% | 2000-01-03 | 2000-01-03 | 1d |  | RP | 8h | 8h | Rel-5 |  |  |  |  |  |  |  |
| 4805 | 1137 | Release 4 Features | 326d? | 2000-01-03 A | 2001-03-30 A | 100% | 2000-01-03 | 2001-03-30 | 326d? |  | NP; GP; RP; SP; TP | 13040h | 13040h | Rel-4 | All |  |  |  |  |  |  |
| 4806 | 15 | **Miscellaneous UE Conformance Testing Activities** | 958d | 2001-04-02 A | 2004-12-01 A | 100% | 2001-04-02 | 2004-12-01 | 958d |  | T1 | 36360h | 36360h | Rel-4 | Ingbert |  | MISTST1 |  |  | MISTST1 |  |
| 4807 | 15.1 | Optimization of Test Time, RF Aspects (FDD) | 508d | 2001-09-24 A | 2003-09-03 A | 100% | 2001-09-24 | 2003-09-03 | 508d | finish no earlier than 2003-09-03 | T1 | 4064h | 4064h | Rel-4 | Ingbert |  | MISTST1-OpFDD |  |  | MISTST1-OpFDD | 34.121 |
| 4808 | 15.2 | Optimization of Test Time, RF Aspects (TDD) | 508d | 2001-09-24 A | 2003-09-03 A | 100% | 2001-09-24 | 2003-09-03 | 508d | finish no earlier than 2003-09-03 | T1 | 4064h | 4064h | Rel-4 | Ingbert |  | MISTST1-OpTDD |  |  | MISTST1-OpTDD | 34.122 |
| 4809 | 15.3 | Extensions to R99 Test cases | 139.4w | 2001-04-02 A | 2003-12-02 A | 100% | 2001-04-02 | 2003-12-02 | 139.4w | finish no earlier than 2003-12-02 | T1 | 5576h | 5576h | Rel-4 | Ingbert |  | MISTST1-Ext |  |  | MISTST1-Ext | 34.123 p 1,2 |
| 4810 | 15.4 | Extension to R99 Test cases - TTCN | 439d | 2002-06-28 A | 2004-03-03 A | 100% | 2002-06-28 | 2004-03-03 | 439d | finish no earlier than 2004-03-03 | T1 | 3512h | 3512h | Rel-4 | Ingbert |  |  |  |  |  |  |
| 4811 | 15.5 | Creation of R99 TCs for TDD - prose | 719d | 2001-10-01 A | 2004-07-01 A | 100% | 2001-10-01 | 2004-07-01 | 719d | finish no earlier than 2004-07-01 | T1 | 5752h | 5752h | Rel-4 | Ingbert |  | MISTST1-TDD |  |  | MISTST1-TDD | 34.123-1 |
| 4812 | 15.6 | Deleted - Creation of R99 TCs for TDD - TTCN | 587d | 2002-09-03 A | 2004-12-01 A | 100% | 2002-09-03 | 2004-12-01 | 587d | finish no earlier than 2004-12-01 | T1 | 4696h | 4696h | Rel-4 | Ingbert | TP-26 |  |  |  |  |  |
| 4813 | 15.7 | Deleted - Review all other work items for impact on new or exiting 34 series specs. | 25.8w | 2002-07-02 A | 2002-12-27 A | 100% | 2002-07-02 | 2002-12-27 | 25.8w | finish no earlier than 2002-12-27 | T1 | 1032h | 1032h | Rel-4 | Ingbert | TP-18 |  |  |  |  | 34.121,122,123,125 |

Notes:
- 4783: Not started. Marked as stopped 12/2008
- 4784: Not started. Marked as stopped 12/2008
- 4785: Not started. Marked as stopped 12/2008
- 4786: Not started. Marked as stopped 12/2008
- 4787: AWS, Nokia, Ericsson, Nortel, Siemens, Motorola
- 4788: AWS, Nokia, Ericsson, Nortel, Siemens, Motorola
- 4789: -
- 4790: -
- 4791: -
- 4792: TERMINATED - NOT STANDARDIZED. Marked as stopped 12/2008
- 4793: TERMINATED - NOT STANDARDIZED. Marked as stopped 12/2008
- 4794: TERMINATED - NOT STANDARDIZED
- 4795: TERMINATED - NOT STANDARDIZED
- 4796: TERMINATED - NOT STANDARDIZED. Marked as stopped 12/2008
- 4797: TERMINATED - NOT STANDARDIZED. Marked as stopped 12/2008
- 4798: TERMINATED - NOT STANDARDIZED. Marked as stopped 12/2008
- 4799: Needed to complete DTM (R99)
- 4800: -
- 4801: -
- 4802: -
- 4803: -
- 4804: -
- 4805: -
- 4806: -
- 4807: It is believed that the current R99 test spec. can be optimised for faster overall test times. Marked as stopped 12/2008 (was 70% complete)
- 4808: It is believed that the current R99 test spec. can be optimised for faster overall test times
- 4809: Further test coverage of the R99 specification to cover supplementry services. Marked as stopped 12/2008 (was 70% complete)
- 4810: Marked as closed 12/2008 (was marked 50% complete)
- 4811: Marked as closed 12/2008 (was marked 50% complete)
- 4812: Marked as stopped 12/2008
- 4813: Marked as stopped 12/2008

| ID | WBS | Task | Duration | Start | Finish | Predecessors | Complete | Baseline start | Baseline finish | Baseline duration | Constraint | Resources | Work | Actual work | Acronym | Release | MCC resp | Acronym_3GU_Export | Impacted TSs and TRs | WI rapporteur name | WI rapporteur e-mail |
| --- | --- | --- | --- | --- | --- | --- | --- | --- | --- | --- | --- | --- | --- | --- | --- | --- | --- | --- | --- | --- | --- |
| 4814 | 46 | **Real Time Facsimile** | 89d | 2000-02-22 A | 2000-06-23 A |  | 100% | 2000-02-22 | 2000-06-23 | 89d |  | S1 | 4376h | 4376h | FAX-RT | Rel-4 | Alain | FAX-RT |  |  |  |
| 4815 | 46.1 | **Real Time Fax** | 89d | 2000-02-22 A | 2000-06-23 A |  | 100% | 2000-02-22 | 2000-06-23 | 89d |  | S2 | 3664h | 3664h |  | Rel-4 | Maurice |  |  |  |  |
| 4816 | 46.1.1 | Terminal capabilities, AT commands | 89d | 2000-02-22 A | 2000-06-23 A |  | 100% | 2000-02-22 | 2000-06-23 | 89d | finish no earlier than 2000-06-23 | T2 | 712h | 712h |  | Rel-4 |  |  | 21.904, 27.007 |  |  |
| 4817 | 46.1.2 | Signalling aspects (e.g. ICM) | 89d | 2000-02-22 A | 2000-06-23 A |  | 100% | 2000-02-22 | 2000-06-23 | 89d | start no earlier than 2000-02-22 | N1 | 712h | 712h |  | Rel-4 | Frederic |  |  |  |  |
| 4818 | 46.1.3 | Service provision | 89d | 2000-02-22 A | 2000-06-23 A |  | 100% | 2000-02-22 | 2000-06-23 | 89d | finish no earlier than 2000-06-23 | N3 | 712h | 712h |  | Rel-4 | Gwiho |  | 23.146 |  |  |
| 4819 | 46.1.4 | Review whether service/stage 1 aspects need to be aligned | 51d | 2000-04-14 A | 2000-06-23 A |  | 100% | 2000-04-14 | 2000-06-23 | 51d | finish no earlier than 2000-12-14 | S1 | 408h | 408h |  | Rel-4 | Alain |  |  |  |  |
| 4820 | 46.1.5 | Review whether architecture/stage 2 aspects need to be aligned | 51d | 2000-04-14 A | 2000-06-23 A |  | 100% | 2000-04-14 | 2000-06-23 | 51d | finish no earlier than 2000-12-14 | S2 | 408h | 408h |  | Rel-4 | Maurice |  |  |  |  |
| 4821 | 47 | Transparent End-to-End PS mobile streaming application | 253d | 2000-04-03 A | 2001-03-21 A |  | 100% | 2000-04-03 | 2001-03-21 | 253d | finish no earlier than 2000-12-29 | S4 | 2024h | 2024h | PSTREAM | Rel-4 | Paolo | PSTREAM | 26.233, 26.234 |  |  |
| 4822 | 48 | **Multimedia Messaging** | 277d | 2000-02-22 A | 2001-03-14 A |  | 100% | 2000-02-22 | 2001-03-14 | 277d |  | T2; S1 | 14424h | 14424h | MMS4 | Rel-4 | Kimmo | MMS, Rel-4 | 22.140, 23.140 | Siemens | Josef.Laumen@SAL.SIEMENS.DE |
| 4823 | 48.1 | Definition of service requirements for Multimedia Messaging | 72d | 2000-02-22 A | 2000-05-31 A |  | 100% | 2000-02-22 | 2000-05-31 | 72d | start no earlier than 2000-02-22 | S1 | 576h | 576h |  | Rel-4 | Alain |  |  |  |  |
| 4824 | 48.2 | Review of definition of service requirements | 205d | 2000-06-01 A | 2001-03-14 A | 4823 | 100% | 2000-06-01 | 2001-03-14 | 205d | finish no earlier than 2000-09-08 | T2 | 1640h | 1640h |  | Rel-4 | Kimmo |  | 22.140, 23.140 | Siemens |  |
| 4825 | 48.3 | **Technical Realisation** | 243d | 2000-04-10 A | 2001-03-14 A |  | 100% | 2000-04-10 | 2001-03-14 | 243d |  | T2 | 7776h | 7776h |  | Rel-4 | Kimmo |  | 22.140, 23.140 | Siemens | Josef.Laumen@SAL.SIEMENS.DE |
| 4826 | 48.3.1 | Review of definition of reference Achitecture model | 243d | 2000-04-10 A | 2001-03-14 A |  | 100% | 2000-04-10 | 2001-03-14 | 243d | finish no earlier than 2001-03-14 | T2 | 1944h | 1944h |  | Rel-4 | Kimmo |  | 22.140, 23.140 | Siemens | Josef.Laumen@SAL.SIEMENS.DE |
| 4827 | 48.3.2 | Fulfill Requirements of Stage 1 | 243d | 2000-04-10 A | 2001-03-14 A |  | 100% | 2000-04-10 | 2001-03-14 | 243d | finish no earlier than 2001-03-14 | T2 | 1944h | 1944h |  | Rel-4 | Kimmo |  | 22.140, 23.140 | Siemens | Josef.Laumen@SAL.SIEMENS.DE |
| 4828 | 48.3.3 | Definition of MMS primitives in Stage 2 | 243d | 2000-04-10 A | 2001-03-14 A |  | 100% | 2000-04-10 | 2001-03-14 | 243d | finish no earlier than 2001-03-14 | T2 | 1944h | 1944h |  | Rel-4 | Kimmo |  | 22.140, 23.140 | Siemens | Josef.Laumen@SAL.SIEMENS.DE |
| 4829 | 49 | **Transcoder-Free Operation** | 326d | 2000-01-03 A | 2001-03-30 A |  | 100% | 2000-01-03 | 2001-03-30 | 326d |  | N4; S2; N1 | 18272h | 18272h | TrFO | Rel-4 | Kimmo | TrFO |  |  |  |
| 4830 | 49.1 | **Out-of-Band Transcoder Control solution** | 326d | 2000-01-03 A | 2001-03-30 A |  | 100% | 2000-01-03 | 2001-03-30 | 326d |  | N4 | 8448h | 8448h | TrFO-OoBTC | Rel-4 | Kimmo | TrFO-OoBTC |  | NEC | Toshiyuki Tamura (tamurato@aj.jp.nec.com) |
| 4831 | 49.1.1 | implementation in UTRAN | 145d | 2000-09-11 A | 2001-03-30 A |  | 100% | 2000-09-11 | 2001-03-30 | 145d | finish no earlier than 2001-03-30 | R3 | 1160h | 1160h | TrFO-OoBTC-UTRAN | Rel-4 | Juha | TrFO-OoBTC-UTRAN | 25.401, 25.410, 25.413, 25.415, 23.153 | Siemens | Alexander Vesely |
| 4832 | 49.1.2 | Impact on architecture, Principles and Terminology | 211d | 2000-01-03 A | 2000-10-20 A |  | 100% | 2000-01-03 | 2000-10-20 | 211d | finish no earlier than 2000-10-20 | S2 | 1680h | 1680h |  | Rel-4 | Maurice |  |  |  |  |
| 4833 | 49.1.3 | Codec Negotiation between UE and MSC | 125d | 2000-08-14 A | 2001-02-02 A |  | 100% | 2000-08-14 | 2001-02-02 | 125d | finish no earlier than 2001-02-02 | N1 | 1000h | 1000h |  | Rel-4 | Frederic |  | 24.008, 23.009, 23.108, (29.002) | Motorola | Andrew Howell |
| 4834 | 49.1.4 | Codec Negotiation inter MSC | 125d | 2000-07-03 A | 2000-12-22 A |  | 100% | 2000-07-03 | 2000-12-22 | 125d | finish no earlier than 2000-12-22 | N4 | 1000h | 1000h |  | Rel-4 | Kimmo |  |  |  |  |
| 4835 | 49.1.5 | Bearer establishment inter MSC | 125d | 2000-07-03 A | 2000-12-22 A |  | 100% | 2000-07-03 | 2000-12-22 | 125d | finish no earlier than 2000-12-22 | N4 | 1000h | 1000h |  | Rel-4 | Kimmo |  | 23.153 |  |  |
| 4836 | 49.2 | **Speech Transcoder: Location and Control at the UMTS Core Network Border** | 125d | 2000-04-10 A | 2000-09-29 A |  | 100% | 2000-04-10 | 2000-09-29 | 125d |  | S2 | 2000h | 2000h | TrFO-STLC | Rel-4 | Maurice | TrFO-STLC |  |  |  |
| 4837 | 49.2.1 | Transcoder at Edge | 125d | 2000-04-10 A | 2000-09-29 A |  | 100% | 2000-04-10 | 2000-09-29 | 125d | finish no earlier than 2000-09-29 | NP | 1000h | 1000h |  | Rel-4 | Kimmo |  |  |  |  |

Notes:
- 4814: -
- 4815: postponed from R99 to R00, SP-000169
- 4816: -
- 4817: -
- 4818: -
- 4819: -
- 4820: -
- 4821: -
- 4822: Acronym changed from "MMS, Rel-4"
- 4823: -
- 4824: -
- 4825: -
- 4826: -
- 4827: e.g. minimum set of media formats, media format conversion, personalization of MMS.
- 4828: -
- 4829: Lead given to CN4 from CN / [DAB 28/11/00]
- 4830: -
- 4831: moved according to NP-000575
- 4832: e.g. study cascading TrFO/TFO/TrFO
- 4833: the link to NP-000085has been deleted because refering to a R99 status sheet / One common set of codec negotiation procedures will be specified as in ID1656.
- 4834: Bearer establishment inter MSC. TS 23.153 R99 part complete. capabilities moved to annex + list of open issues
- 4835: Bearer establishment inter MSC. TS 23.153 R99 part complete. capabilities moved to annex. / See NP-000127 / Open issues: / Handling of Conference Calls; / Handling of Multi Party Supplementary Services; / Handling of Handover UMTS to GSM; / Handling of Sending a ...
- 4836: WI description and Tdoc S2-99352 / Speech Transcoder: Location and Control at the UMTS Core Network Border
- 4837: WI description and Tdoc S2-99352...

| ID | WBS | Task | Duration | Start | Finish | Complete | Baseline start | Baseline finish | Baseline duration | Constraint | Resources | Work | Actual work | Acronym | Release | MCC resp | Acronym_3GU_Export | WI rapporteur name | WI rapporteur e-mail |
| --- | --- | --- | --- | --- | --- | --- | --- | --- | --- | --- | --- | --- | --- | --- | --- | --- | --- | --- | --- |
| 4838 | 50 | **GERAN improvements 1 (Gb over IP)** | 225d | 2000-05-09 A | 2001-03-19 A | 100% | 2000-05-09 | 2001-03-19 | 225d |  | GP | 6472h | 6472h | GEIMP1 | Rel-4 | Paolo | GEIMP1 |  |  |
| 4839 | 50.1 | **Gb over IP (Ip-fication of Gb)** | 225d | 2000-05-09 A | 2001-03-19 A | 100% | 2000-05-09 | 2001-03-19 | 225d |  | GP | 4672h | 4672h | GbIP | Rel-4 | Paolo | GbIP |  |  |
| 4840 | 50.1.1 | Concept of Gb over IP (Ip-fication of Gb) | 134d | 2000-05-09 A | 2000-11-10 A | 100% | 2000-05-09 | 2000-11-10 | 134d |  | GP | 1072h | 1072h |  | Rel-4 | Paolo |  |  |  |
| 4841 | 50.1.2 | Changes to 08.16, 08.18 | 225d | 2000-05-09 A | 2001-03-19 A | 100% | 2000-05-09 | 2001-03-19 | 225d |  | GP | 1800h | 1800h |  | Rel-4 | Paolo |  |  |  |
| 4842 | 51 | **GERAN improvements 2 (NACC)** | 677d | 2000-11-06 A | 2003-06-10 A | 100% | 2000-11-06 | 2003-06-10 | 677d |  | GP | 22408h | 22408h | GEIMP2 | Rel-4 | Paolo | GEIMP2 |  |  |
| 4843 | 51.1 | **Gb enhancements** | 155d | 2000-11-06 A | 2001-06-08 A | 100% | 2000-11-06 | 2001-06-08 | 155d |  | GP | 7440h | 7440h | Gben | Rel-4 | Paolo | Gben |  |  |
| 4844 | 51.1.1 | **Intra BSC NACC (Network Assisted Cell Change)** | 155d | 2000-11-06 A | 2001-06-08 A | 100% | 2000-11-06 | 2001-06-08 | 155d |  | GP | 6200h | 6200h |  | Rel-4 | Paolo |  |  |  |
| 4845 | 51.1.1.1 | Concept | 155d | 2000-11-06 A | 2001-06-08 A | 100% | 2000-11-06 | 2001-06-08 | 155d | finish no earlier than 2001-06-08 | GP | 1240h | 1240h |  | Rel-4 | Paolo |  |  |  |
| 4846 | 51.1.1.2 | Changes in 03.64 | 155d | 2000-11-06 A | 2001-06-08 A | 100% | 2000-11-06 | 2001-06-08 | 155d | finish no earlier than 2001-06-08 | GP | 1240h | 1240h |  | Rel-4 | Paolo |  |  |  |
| 4847 | 51.1.1.3 | Changes in 04.60 | 155d | 2000-11-06 A | 2001-06-08 A | 100% | 2000-11-06 | 2001-06-08 | 155d | finish no earlier than 2001-06-08 | GP | 1240h | 1240h |  | Rel-4 | Paolo |  |  |  |
| 4848 | 51.1.1.4 | Changes in 44.008 | 155d | 2000-11-06 A | 2001-06-08 A | 100% | 2000-11-06 | 2001-06-08 | 155d | finish no earlier than 2001-06-08 | GP | 1240h | 1240h |  | Rel-4 | Paolo |  |  |  |
| 4849 | 51.3 | **MS conformance test for Intra BSC NACC** | 398d | 2001-11-30 A | 2003-06-10 A | 100% | 2001-11-30 | 2003-06-10 | 398d |  | GP | 9552h | 9552h | GEIMP2-Msconf | Rel-4 | Paolo | GEIMP2-Msconf |  |  |
| 4850 | 51.3.1 | Changes in 51.010 | 398d | 2001-11-30 A | 2003-06-10 A | 100% | 2001-11-30 | 2003-06-10 | 398d | finish no earlier than 2003-12-19 | G5; G4 | 6368h | 6368h |  | Rel-4 | Paolo |  |  |  |
| 4851 | 52 | **GERAN improvements 4 (Delayed TBF)** | 105d | 2001-01-15 A | 2001-06-08 A | 100% | 2001-01-15 | 2001-06-08 | 105d |  | GP | 3960h | 3960h | GEIMP4 | Rel-4 | Paolo | GEIMP4 |  |  |
| 4852 | 52.1 | **Gb enhancements 2** | 105d | 2001-01-15 A | 2001-06-08 A | 100% | 2001-01-15 | 2001-06-08 | 105d |  | GP | 3120h | 3120h | GEIMP4-Gben2 | Rel-4 | Paolo | GEIMP4-Gben2 |  |  |
| 4853 | 52.1.1 | Stage 2 for Gb enhancements 2 | 105d | 2001-01-15 A | 2001-06-08 A | 100% | 2001-01-15 | 2001-06-08 | 105d | finish no earlier than 2001-06-08 | GP | 840h | 840h |  | Rel-4 | Paolo |  |  |  |
| 4854 | 52.1.2 | **Stage 3 (changes in 44.060)** | 60d | 2001-01-15 A | 2001-04-06 A | 100% | 2001-01-15 | 2001-04-06 | 60d |  | G2 | 1440h | 1440h |  | Rel-4 | Gert |  |  |  |
| 4855 | 52.1.2.1 | Definition of enhanced countdown procedure | 60d | 2001-01-15 A | 2001-04-06 A | 100% | 2001-01-15 | 2001-04-06 | 60d | finish no earlier than 2001-04-06 | G2 | 480h | 480h |  | Rel-4 | Gert |  |  |  |
| 4856 | 52.1.2.2 | Definition of enhanced TBF release procedure | 60d | 2001-01-15 A | 2001-04-06 A | 100% | 2001-01-15 | 2001-04-06 | 60d | finish no earlier than 2001-04-06 | G2 | 480h | 480h |  | Rel-4 | Gert |  |  |  |
| 4857 | 52.1.2.3 | Definition of USF=FREE type polling mechanism on PDCH | 60d | 2001-01-15 A | 2001-04-06 A | 100% | 2001-01-15 | 2001-04-06 | 60d | finish no earlier than 2001-04-06 | G2 | 480h | 480h |  | Rel-4 | Gert |  |  |  |
| 4858 | 53 | **Low Chip Rate TDD option** | 880d | 2000-07-19 A | 2003-12-02 A | 100% | 2000-07-19 | 2003-12-02 | 880d |  | R1 | 27488h | 27488h | LCRTDD | Rel-4 | Patrick | LCRTDD | CWTS | G. Yang |
| 4859 | 53.1 | Physical layer for Low Chip Rate TDD option | 183d | 2000-07-19 A | 2001-03-30 A | 100% | 2000-07-19 | 2001-03-30 | 183d | finish no earlier than 2001-03-30 | R1 | 1464h | 1464h | LCRTDD-Phys | Rel-4 | Patrick | LCRTDD-Phys | CWTS | G. Yang |
| 4860 | 53.2 | Layer 2 and layer 3 protocol aspects | 183d | 2000-07-19 A | 2001-03-30 A | 100% | 2000-07-19 | 2001-03-30 | 183d | finish no earlier than 2001-03-30 | R2 | 1464h | 1464h | LCRTDD-L23 | Rel-4 | Yong-Jun | LCRTDD-L23 | CWTS | Y. Liu |
| 4861 | 53.3 | RF radio transmission/reception, system performance requirements and conformance testing | 165d | 2000-08-14 A | 2001-03-30 A | 100% | 2000-08-14 | 2001-03-30 | 165d | finish no earlier than 2001-03-30 | R4 | 1320h | 1320h | LCRTDD-RF | Rel-4 | Issam | LCRTDD-RF | CWTS | D. Zhang |
| 4862 | 53.4 | UE radio access capability | 165d | 2000-08-14 A | 2001-03-30 A | 100% | 2000-08-14 | 2001-03-30 | 165d | finish no earlier than 2001-03-30 | R2 | 1320h | 1320h | LCRTDD-UErac | Rel-4 | Yong-Jun | LCRTDD-UErac | CWTS | Y. Liu |
| 4863 | 53.5 | Iub/Iur protocol aspects - for Low Chip Rate TDD option | 165d | 2000-08-14 A | 2001-03-30 A | 100% | 2000-08-14 | 2001-03-30 | 165d | finish no earlier than 2001-03-30 | R3 | 1320h | 1320h | LCRTDD-IubIur | Rel-4 | Juha | LCRTDD-IubIur | CWTS | Y. Liu |

Notes:
- 4838: -
- 4839: -
- 4840: -
- 4841: -
- 4842: -
- 4843: -
- 4844: -
- 4845: -
- 4846: -
- 4847: -
- 4848: -
- 4849: -
- 4850: az 05/08: duplicated UID_50099 => 50299. Marked as closed 12/2008 (was marked 50% complete)
- 4851: -
- 4852: -
- 4853: -
- 4854: -
- 4855: -
- 4856: -
- 4857: -
- 4858: -
- 4859: -
- 4860: -
- 4861: -
- 4862: -
- 4863: -

| ID | WBS | Task | Duration | Start | Finish | Predecessors | Complete | Baseline start | Baseline finish | Baseline duration | Constraint | Resources | Work | Actual work | Release | MCC resp | Impacted TSs and TRs | TSG stopped | Acronym | WI rapporteur name | WI rapporteur e-mail | Acronym_3GU_Export |
| --- | --- | --- | --- | --- | --- | --- | --- | --- | --- | --- | --- | --- | --- | --- | --- | --- | --- | --- | --- | --- | --- | --- |
| 4864 | 53.6 | **Low chiprate TDD interworking with GERAN** | 101d | 2000-09-01 A | 2001-01-19 A | 4863 | 100% | 2000-09-01 | 2001-01-19 | 101d |  | GP | 1616h | 1616h | Rel-4 | Paolo |  |  |  |  |  |  |
| 4865 | 53.6.1 | Handover and Cell Selection / Reselection to UTRA 1.28 Mcps TDD | 101d | 2000-09-01 A | 2001-01-19 A |  | 100% | 2000-09-01 | 2001-01-19 | 101d | finish no earlier than 2001-01-19 | GP | 808h | 808h | Rel-4 | Paolo |  |  |  |  |  |  |
| 4866 | 53.8 | **Conformance Test Aspects - Low Chip Rate TDD** | 577d | 2001-09-17 A | 2003-12-02 A | 4864 | 100% | 2001-09-17 | 2003-12-02 | 577d |  | T1 | 12088h | 12088h | Rel-4 | Ingbert |  |  |  |  |  |  |
| 4867 | 53.8.1 | Testing Layer 2 and layer 3 protocol aspects | 468d | 2001-09-17 A | 2003-07-02 A |  | 100% | 2001-09-17 | 2003-07-02 | 468d | finish no earlier than 2003-07-02 | T1 | 3744h | 3744h | Rel-4 | Ingbert | 34.123-1, 34.123-2 |  |  |  |  |  |
| 4868 | 53.8.2 | Deleted - Testing Layer 2 and layer 3 protocol aspects - TTCN | 261d | 2002-12-03 A | 2003-12-02 A |  | 100% | 2002-12-03 | 2003-12-02 | 261d | finish no earlier than 2003-12-02 | T1 | 2088h | 2088h | Rel-4 | Ingbert | 34.123-3 | TP-22 |  |  |  |  |
| 4869 | 53.8.3 | Testing RF Radio Transmission and Reception | 205d | 2001-09-17 A | 2002-06-28 A |  | 100% | 2001-09-17 | 2002-06-28 | 205d | finish no earlier than 2002-06-28 | T1 | 1640h | 1640h | Rel-4 | Ingbert |  |  |  |  |  |  |
| 4870 | 54 | **Enable bearer independent CS architecture** | 566d | 2000-01-03 A | 2002-03-01 A |  | 100% | 2000-01-03 | 2002-03-01 | 566d |  | S2; N3; N4 | 28008h | 28008h | Rel-4 | Maurice |  |  | CSSPLIT | Siemens | Alexander Milinski | CSSPLIT |
| 4871 | 54.1 | **Enable bearer-independent call control** | 425d | 2000-01-03 A | 2001-08-16 A |  | 100% | 2000-01-03 | 2001-08-16 | 425d |  | N4 | 12344h | 12344h | Rel-4 | Kimmo |  |  |  | Ericsson | Heinz-Peter.Keutmann@eed.ericsson.se |  |
| 4872 | 54.1.1 | Architecture and Stage 2 description | 181d | 2000-01-03 A | 2000-09-08 A |  | 100% | 2000-01-03 | 2000-09-08 | 181d | finish no earlier than 2000-09-08 | S2 | 1440h | 1440h | Rel-4 | Maurice | 23.002 |  |  |  |  |  |
| 4873 | 54.1.2 | Standardisation of protocols (control & user planes) over Nb interface | 64d | 2001-01-02 A | 2001-03-30 A |  | 100% | 2001-01-02 | 2001-03-30 | 64d | finish no earlier than 2001-03-30 | N3 | 512h | 512h | Rel-4 | Gwiho |  |  |  |  |  |  |
| 4874 | 54.1.3 | Standardisation of protocols over reference points between MSC server and Gateway MSC server | 130d | 2000-09-25 A | 2001-03-23 A |  | 100% | 2000-09-25 | 2001-03-23 | 130d | finish no earlier than 2001-03-23 | N4 | 1040h | 1040h | Rel-4 | Kimmo |  |  |  |  |  |  |
| 4875 | 54.1.4 | Standardisation of detailed stage 2 description | 180d | 2000-07-17 A | 2001-03-23 A |  | 100% | 2000-07-17 | 2001-03-23 | 180d | finish no earlier than 2001-03-23 | N4 | 1440h | 1440h | Rel-4 | Kimmo |  |  |  |  |  |  |
| 4876 | 54.1.5 | **Bearer control between MSC server and MGW** | 250d | 2000-09-01 A | 2001-08-16 A |  | 100% | 2000-09-01 | 2001-08-16 | 250d |  | N4 | 4512h | 4512h | Rel-4 | Kimmo |  |  |  |  |  |  |
| 4877 | 54.1.5.1 | stage 3 - protocol issues | 250d | 2000-09-01 A | 2001-08-16 A |  | 100% | 2000-09-01 | 2001-08-16 | 250d | finish no earlier than 2001-08-16 | N4 | 2000h | 2000h | Rel-4 | Kimmo |  |  |  |  |  |  |
| 4878 | 54.1.5.2 | stage 3 - parameter value issues | 64d | 2001-01-02 A | 2001-03-30 A |  | 100% | 2001-01-02 | 2001-03-30 | 64d | finish no earlier than 2001-03-30 | N3 | 512h | 512h | Rel-4 | Gwiho |  |  |  |  |  |  |
| 4879 | 54.4 | Deleted - Conformance Test Aspects - Enable bearer independent CS architecture | 260d | 2001-03-05 A | 2002-03-01 A |  | 100% | 2001-03-05 | 2002-03-01 | 260d |  | T1 | 2080h | 2080h | Rel-4 | Ingbert |  | TP-15 | CSSPLIT-TEST |  |  | CSSPLIT-TEST |
| 4880 | 55 | **MExE enhancements Rel-4** | 511d | 2000-01-03 A | 2001-12-14 A |  | 100% | 2000-01-03 | 2001-12-14 | 511d |  | T2; S3 | 26912h | 26912h | Rel-4 | Kimmo |  |  | MEXE |  |  | MEXE |
| 4881 | 55.1 | **MExE Security Analysis Activity** | 474d | 2000-02-22 A | 2001-12-14 A |  | 100% | 2000-02-22 | 2001-12-14 | 474d |  | S3; T2 | 12256h | 12256h | Rel-4 | Mirko |  |  | MEXE-SEC | BT | Andrew.Myers@bt.com | MEXE-SEC |
| 4882 | 55.1.1 | Stage 3 for MExE Security | 370d | 2000-07-17 A | 2001-12-14 A |  | 100% | 2000-07-17 | 2001-12-14 | 370d | finish no earlier than 2001-12-14 | S3 | 2960h | 2960h | Rel-4 | Mirko | 21.133, 33.102 |  |  | BT | Andrew.Myers@bt.com |  |
| 4883 | 55.1.2 | Terminal aspects for MExE Security | 214d | 2000-02-22 A | 2000-12-15 A |  | 100% | 2000-02-22 | 2000-12-15 | 214d | finish no earlier than 2000-12-15 | T2 | 1712h | 1712h | Rel-4 |  | 23.057 |  |  | BT | Andrew.Myers@bt.com |  |
| 4884 | 55.2 | **MExE Rel-4 Improvements and Investigations** | 251d | 2000-01-03 A | 2000-12-15 A |  | 100% | 2000-01-03 | 2000-12-15 | 251d |  | T2 | 6480h | 6480h | Rel-4 | Kimmo | 22.057, 23.057 |  | MEXE-ENHANC | Motorola | Mark Cataldo | MEXE-ENHANC |
| 4885 | 55.2.1 | 3rd MExE classmark | 251d | 2000-01-03 A | 2000-12-15 A |  | 100% | 2000-01-03 | 2000-12-15 | 251d | finish no earlier than 2000-12-15 | T2 | 2000h | 2000h | Rel-4 | Kimmo | 22.057, 23.057 |  |  | Motorola | Mark Cataldo |  |
| 4886 | 55.2.2 | FS on Secure download mechanism and capabilities to support SDR concepts | 225d | 2000-02-07 A | 2000-12-15 A |  | 100% | 2000-02-07 | 2000-12-15 | 225d | finish no earlier than 2000-12-15 | T2 | 1800h | 1800h | Rel-4 | Kimmo | 22.057, 23.057 |  |  | Motorola | Mark Cataldo |  |
| 4887 | 55.2.3 | FS on Support of MP3/MPEG4 content | 225d | 2000-02-07 A | 2000-12-15 A |  | 100% | 2000-02-07 | 2000-12-15 | 225d | finish no earlier than 2000-12-15 | T2 | 1800h | 1800h | Rel-4 | Kimmo | 22.057, 23.057 |  |  | Motorola | Mark Cataldo |  |

Notes:
- 4864: -
- 4865: -
- 4866: -
- 4867: Marked as closed 12/2008 (was marked 60% complete)
- 4868: Marked as stopped 12/2008
- 4869: duration set to 6 months (was 0), finish date set
- 4870: -
- 4871: DAB 12.12.01 should be 100% hence closed
- 4872: R00 stage 2 at least 80 % complete in TSGS #8 21.-23.6.2000
- 4873: -
- 4874: -
- 4875: -
- 4876: -
- 4877: -
- 4878: -
- 4879: Marked as stopped 12/2008
- 4880: -
- 4881: SP#12 updated WID
- 4882: -
- 4883: -
- 4884: -
- 4885: Additional features for MExE R2000
- 4886: -
- 4887: -

| ID | WBS | Task | Duration | Start | Finish | Complete | Baseline start | Baseline finish | Baseline duration | Constraint | Resources | Work | Actual work | Acronym | Release | MCC resp | Acronym_3GU_Export | Impacted TSs and TRs | WI rapporteur name | WI rapporteur e-mail |
| --- | --- | --- | --- | --- | --- | --- | --- | --- | --- | --- | --- | --- | --- | --- | --- | --- | --- | --- | --- | --- |
| 4888 | 56 | **Tandem Free aspects for 3G and between 2G and 3G systems** | 344d | 2000-02-22 A | 2001-06-15 A | 100% | 2000-02-22 | 2001-06-15 | 344d |  | S4 | 9696h | 9696h | TFO | Rel-4 | Paolo | TFO |  |  |  |
| 4889 | 56.1 | **Tandem Free AMR** | 344d | 2000-02-22 A | 2001-06-15 A | 100% | 2000-02-22 | 2001-06-15 | 344d |  | S4 | 6944h | 6944h | TFO-AMR | Rel-4 | Paolo | TFO-AMR |  |  |  |
| 4890 | 56.1.1 | Specification of Tandem Free AMR | 284d | 2000-02-22 A | 2001-03-23 A | 100% | 2000-02-22 | 2001-03-23 | 284d | start no earlier than 2000-02-22 | S4 | 2272h | 2272h |  | Rel-4 | Paolo |  | 28.062 |  |  |
| 4891 | 56.1.2 | **Impact of Tandem Free AMR on:** | 115d | 2001-01-08 A | 2001-06-15 A | 100% | 2001-01-08 | 2001-06-15 | 115d |  | NP | 1920h | 1920h |  | Rel-4 | Kimmo |  |  |  |  |
| 4892 | 56.1.2.1 | CN | 60d | 2001-03-26 A | 2001-06-15 A | 100% | 2001-03-26 | 2001-06-15 | 60d | finish no earlier than 2001-06-15 | NP | 480h | 480h |  | Rel-4 | Kimmo |  |  |  |  |
| 4893 | 56.1.2.2 | GERAN | 65d | 2001-01-08 A | 2001-04-06 A | 100% | 2001-01-08 | 2001-04-06 | 65d | finish no earlier than 2001-04-06 | GP | 520h | 520h |  | Rel-4 | Paolo |  |  |  |  |
| 4894 | 57 | **Advanced Speech Call Items enhancements_Rel-4** | 334d | 2000-12-03 A | 2002-03-14 A | 100% | 2000-12-03 | 2002-03-14 | 334d |  | N1 | 5925.6h | 5925.6h | ASCI4 | Rel-4 | Frederic | ASCI, Rel-4 |  | Nortel | sonia.garapaty@nortelnetworks.com |
| 4895 | 57.1 | Stage 2 for Advanced Speech Call Items enhancements_Rel-4 (ASCI) | 326.7d | 2000-12-03 A | 2002-03-14 A | 100% | 2000-12-03 | 2002-03-14 | 326.7d | finish no earlier than 2002-03-14 | N4 | 2613.6h | 2613.6h |  | Rel-4 | Kimmo |  | 23.067, 24.067 | Sagem | Vivien Perlic |
| 4896 | 57.2 | Stages 2 and 3 on A interface | 80d | 2000-12-03 A | 2001-03-23 A | 100% | 2000-12-03 | 2001-03-23 | 80d | finish no earlier than 2001-03-23 | N1 | 640h | 640h |  | Rel-4 | Frederic |  | 44.068, 44.069, 24.008 | Nortel | sonia.garapaty@nortelnetworks.com |
| 4897 | 58 | **700 MHz spectrum support** | 776d | 2000-01-03 A | 2002-12-20 A | 100% | 2000-01-03 | 2002-12-20 | 776d |  | GP | 20016h | 20016h | 700SS | Rel-4 | Paolo | 700SS |  |  |  |
| 4898 | 58.1 | **GERAN support for the 700 MHz band** | 276d | 2000-01-03 A | 2001-01-19 A | 100% | 2000-01-03 | 2001-01-19 | 276d |  | GP | 8808h | 8808h |  | Rel-4 | Paolo |  |  |  |  |
| 4899 | 58.1.1 | Signalling support | 276d | 2000-01-03 A | 2001-01-19 A | 100% | 2000-01-03 | 2001-01-19 | 276d | finish no earlier than 2001-01-19 | GP | 2200h | 2200h |  | Rel-4 | Paolo |  |  |  |  |
| 4900 | 58.1.2 | Physical layer definitions - for GERAN support for the 700 MHz band | 276d | 2000-01-03 A | 2001-01-19 A | 100% | 2000-01-03 | 2001-01-19 | 276d | finish no earlier than 2001-01-19 | GP | 2200h | 2200h |  | Rel-4 | Paolo |  |  |  |  |
| 4901 | 58.1.3 | Receiver performance and RF budget | 276d | 2000-01-03 A | 2001-01-19 A | 100% | 2000-01-03 | 2001-01-19 | 276d | finish no earlier than 2001-01-19 | GP | 2200h | 2200h |  | Rel-4 | Paolo |  |  |  |  |
| 4902 | 58.2 | GERAN MS Conformance test for 700 MHz band | 175d | 2001-04-02 A | 2001-11-30 A | 100% | 2001-04-02 | 2001-11-30 | 175d |  | GP | 1400h | 1400h |  | Rel-4 | Paolo |  |  |  |  |
| 4903 | 58.3 | GERAN BTS Conformance test for 700 MHz band | 450d | 2001-04-02 A | 2002-12-20 A | 100% | 2001-04-02 | 2002-12-20 | 450d |  | GP | 3600h | 3600h |  | Rel-4 | Paolo |  |  |  |  |
| 4904 | 59 | Operator Determined Barring for Packet Oriented Services | 208d | 2000-06-01 A | 2001-03-19 A | 100% | 2000-06-01 | 2001-03-19 | 208d | finish no earlier than 2001-03-19 | NP | 1664h | 1664h | ODB | Rel-4 | Kimmo | ODB |  | NEC | Toshiyuki Tamura (tamurato@aj.jp.nec.com) |
| 4905 | 60 | **UMTS QoS Architecture for PS Domain** | 759d | 2000-01-03 A | 2002-11-27 A | 100% | 2000-01-03 | 2002-11-27 | 759d |  | S2; S5; R3; GP | 72848h | 72848h | QoSPS | Rel-4 | Maurice | QoSPS |  | Ericsson | Ina.widegren@era.ericsson.se |
| 4906 | 60.1 | Architecture | 153d | 2000-06-05 A | 2001-01-03 A | 100% | 2000-06-05 | 2001-01-03 | 153d | finish no earlier than 2001-01-03 | S2 | 1224h | 1224h |  | Rel-4 | Maurice |  | 23.107 |  |  |
| 4907 | 60.2 | Charging and OAM&P for QoS Management | 201d | 2001-09-21 A | 2002-06-28 A | 100% | 2001-09-21 | 2002-06-28 | 201d | finish no earlier than 2002-06-28 | S5 | 1608h | 1608h | QoSPS-OAM | Rel-4 | Mirko | QoSPS-OAM | 32-series |  |  |
| 4908 | 60.3 | **RAB Quality of Service (re)Negotiation over Iu** | 155d | 2000-08-21 A | 2001-03-23 A | 100% | 2000-08-21 | 2001-03-23 | 155d |  | R3 | 3648h | 3648h | QoSPS-MAPEND-RABQoS | Rel-4 | Juha | QoSPS-MAPEND-RABQoS | 25.413 | Ericsson | anders.molander@ericsson.com |
| 4909 | 60.3.1 | RAB Quality of Service Negotiation over Iu | 155d | 2000-08-21 A | 2001-03-23 A | 100% | 2000-08-21 | 2001-03-23 | 155d | finish no earlier than 2001-03-23 | R3 | 1240h | 1240h | QoSPS-MAPEND-RABQoS-Negot | Rel-4 | Juha | QoSPS-MAPEND-RABQoS-Negot |  | Ericsson | anders.molander@ericsson.com |
| 4910 | 60.3.2 | RAB Quality of Service Negotiation over Iu during relocation | 16d | 2001-03-02 A | 2001-03-23 A | 100% | 2001-03-02 | 2001-03-23 | 16d | start no earlier than 2001-03-02 | R3 | 128h | 128h | QoSPS-MAPEND-RABQoS-NegotReloc | Rel-4 | Juha | QoSPS-MAPEND-RABQoS-NegotReloc |  |  |  |
| 4911 | 60.3.3 | RAB Quality of Service Re-Negotiation over Iu | 130d | 2000-09-25 A | 2001-03-23 A | 100% | 2000-09-25 | 2001-03-23 | 130d | finish no earlier than 2001-03-23 | R3 | 1040h | 1040h | QoSPS-MAPEND-RABQoS-ReNegot | Rel-4 | Juha | QoSPS-MAPEND-RABQoS-ReNegot |  | Motorola | S. Irwin |

Notes:
- 4888: RAN and CN to verify no problems for GSM terminals roaming in 3G R99
- 4889: RAN and CN to verify UMTS_AMR_2 support
- 4890: -
- 4891: "Implementation" changed to "Impact on:" by A. Sultan (for better wording)
- 4892: RAN and CN to verify UMTS_AMR_2 support
- 4893: End date Modified from June to March to have it in Rel4
- 4894: Approved at CN#10. Acronym changed from ASCI, Rel-4
- 4895: CN4#11 30/11/02: no inputs received in CN4
- 4896: -
- 4897: -
- 4898: -
- 4899: -
- 4900: -
- 4901: -
- 4902: -
- 4903: -
- 4904: Completed WI missing from the P-plan Added for tracking
- 4905: -
- 4906: -
- 4907: -
- 4908: -
- 4909: -
- 4910: -
- 4911: -

| ID | WBS | Task | Type | Duration | Start | Finish | Complete | Baseline start | Baseline finish | Baseline duration | Constraint | Resources | Work | Actual work | Acronym | Release | MCC resp | Acronym_3GU_Export | TSG stopped | WI rapporteur name | WI rapporteur e-mail | Impacted TSs and TRs |
| --- | --- | --- | --- | --- | --- | --- | --- | --- | --- | --- | --- | --- | --- | --- | --- | --- | --- | --- | --- | --- | --- | --- |
| 4912 | 60.4 | **GERAN QoS Aspects - Handovers: maintenance of real-time QoS while moving between cells in the PLMN including inter-SGSN and SRNS relocation or possibly other mechanisms** |  | 501d | 2000-01-03 A | 2001-11-30 A | 100% | 2000-01-03 | 2001-11-30 | 501d |  | GP | 14456h | 14456h | GERQoS | Rel-4 | Paolo | GERQoS |  |  |  |  |
| 4913 | 60.4.1 | **Handover Concept for the PS domain** |  | 501d | 2000-01-03 A | 2001-11-30 A | 100% | 2000-01-03 | 2001-11-30 | 501d |  | GP | 10448h | 10448h |  | Rel-4 | Paolo |  |  |  |  |  |
| 4914 | 60.4.1.1 | Stable RT handover report 25.936 including header removal |  | 14d | 2000-01-03 A | 2000-01-19 A | 100% | 2000-01-03 | 2000-01-19 | 14d | start no earlier than 2000-01-03 | GP | 104h | 104h |  | Rel-4 | Paolo |  |  |  |  |  |
| 4915 | 60.4.1.2 | Update of stage 2 |  | 293d | 2000-01-03 A | 2001-02-13 A | 100% | 2000-01-03 | 2001-02-13 | 293d | finish no earlier than 2001-02-13 | GP | 2336h | 2336h |  | Rel-4 | Paolo |  |  |  |  |  |
| 4916 | 60.4.1.3 | Update of relevant stage 3 specs -> RRC |  | 501d | 2000-01-03 A | 2001-11-30 A | 100% | 2000-01-03 | 2001-11-30 | 501d | finish no earlier than 2001-11-30 | G2 | 4000h | 4000h |  | Rel-4 | Gert |  |  |  |  |  |
| 4917 | 60.5 | **Deleted - GERAN MS Conformance test for inter-system and intra-system Packet data real-time Handover** |  | 324d | 2001-08-31 A | 2002-11-27 A | 100% | 2001-08-31 | 2002-11-27 | 324d |  | G4; R3 | 25920h | 25920h | GERQoS-Mstest | Rel-4 | Paolo | GERQoS-Mstest | GP-12 |  |  |  |
| 4918 | 60.5.1 | **Deleted - Handover for the PS domain** |  | 324d | 2001-08-31 A | 2002-11-27 A | 100% | 2001-08-31 | 2002-11-27 | 324d |  | G4; R3 | 20736h | 20736h |  | Rel-4 | Paolo |  | GP-12 |  |  |  |
| 4919 | 60.5.1.1 | Deleted - Stable RT handover report 25.936 including header removal |  | 324d | 2001-08-31 A | 2002-11-27 A | 100% | 2001-08-31 | 2002-11-27 | 324d | finish no earlier than 2002-11-27 | G4; R3 | 5184h | 5184h |  | Rel-4 | Paolo |  | GP-12 |  |  |  |
| 4920 | 60.5.1.2 | Deleted - Update of stage 2 |  | 324d | 2001-08-31 A | 2002-11-27 A | 100% | 2001-08-31 | 2002-11-27 | 324d | finish no earlier than 2002-11-27 | G4; R3 | 5184h | 5184h |  | Rel-4 | Paolo |  | GP-12 |  |  |  |
| 4921 | 60.5.1.3 | Deleted - Update of relevant stage 3 specs |  | 324d | 2001-08-31 A | 2002-11-27 A | 100% | 2001-08-31 | 2002-11-27 | 324d | finish no earlier than 2002-11-27 | G4; R3 | 5184h | 5184h |  | Rel-4 | Paolo |  | GP-12 |  |  |  |
| 4922 | 60.6 | PS-domain handover for real-time services |  | 155d | 2000-08-28 A | 2001-03-30 A | 100% | 2000-08-28 | 2001-03-30 | 155d | finish no earlier than 2001-03-30 | R3 | 1240h | 1240h | QoSPS-PSdoRTS | Rel-4 | Juha | QoSPS-PSdoRTS |  | Nokia | atte.lansisalmi@nokia.com |  |
| 4923 | 60.7 | Deleted - RAB QoS Renegotiation at Relocation |  | 58d | 2001-01-03 A | 2001-03-23 A | 100% | 2001-01-03 | 2001-03-23 | 58d | finish no earlier than 2001-03-23 | R3 | 464h | 464h |  | Rel-4 | Juha |  | RP-11 |  |  | 25.851, 25.946 |
| 4924 | 61 | (Small) Technical Enhancements and Improvements for Rel-4 | milestone | 0d? | 2000-01-03 A | 2000-01-03 A | 100% | 2000-01-03 | 2001-03-30 | 326d? |  | SP; CP; RP; GP |  |  | TEI4 | Rel-4 | all | TEI4 |  |  |  |  |
| 4925 | 1155 | Test - (Small) Technical Enhancements and Improvements for Rel-4 |  | 326d? | 2000-01-03 A | 2001-03-30 A | 100% | 2000-01-03 | 2001-03-30 | 326d? | finish no earlier than 2008-12-31 | R5; T1 | 5216h | 5216h | TEI4_Test | Rel-4 | Ingbert | TEI4_Test |  |  |  |  |
| 4926 | 62 | **Rel-4 Evolutions of the transport in the UTRAN** |  | 525d | 2000-08-21 A | 2002-08-23 A | 100% | 2000-08-21 | 2002-08-23 | 525d |  | RP | 8600h | 8600h | ETRAN | Rel-4 | Issam | ETRAN |  | Alcatel | Francois Courau |  |
| 4927 | 62.1 | QoS optimization for AAL2 connections over Iub and Iur interfaces |  | 160d | 2000-08-21 A | 2001-03-30 A | 100% | 2000-08-21 | 2001-03-30 | 160d | finish no earlier than 2001-03-30 | R3 | 1280h | 1280h | ETRAN-QoSAAL2 | Rel-4 | Juha | ETRAN-QoSAAL2 |  | Japan Telecom | T. Yoshimura |  |
| 4928 | 62.2 | Transport bearer modification procedure on Iub, Iur, and Iu |  | 130d | 2000-10-02 A | 2001-03-30 A | 100% | 2000-10-02 | 2001-03-30 | 130d | finish no earlier than 2001-03-30 | R3 | 1040h | 1040h | ETRAN-MigrMod | Rel-4 | Juha | ETRAN-MigrMod |  | Japan Telecom | T. Yoshimura |  |
| 4929 | 62.3 | **Deleted - Conformance Test Aspects of Rel-4 evolutions of the transport in UTRAN** |  | 130d | 2002-02-25 A | 2002-08-23 A | 100% | 2002-02-25 | 2002-08-23 | 130d |  | T1 | 2080h | 2080h |  | Rel-4 | Ingbert |  | TP-17 |  |  |  |
| 4930 | 62.3.1 | Deleted - Testing RAB support enhancements |  | 130d | 2002-02-25 A | 2002-08-23 A | 100% | 2002-02-25 | 2002-08-23 | 130d | finish no earlier than 2002-08-23 | T1 | 1040h | 1040h | CT-RABS? | Rel-4 | Ingbert | CT-RABS? | TP-17 |  |  | 34.108, 34. 121, 34.122, 34.123 p 1,2, 34.123 pt 3 |
| 4931 | 63 | **Rel-4 Evolutions of the transport in the CN** |  | 215d | 2000-05-29 A | 2001-03-23 A | 100% | 2000-05-29 | 2001-03-23 | 215d |  | N4; N1; N2; S2 | 13128h | 13128h | CNTRSP | Rel-4 | Kimmo | CNTRSP |  |  |  |  |
| 4932 | 63.1 | **IP Transport of CN protocols (e.g. CAP, MAP)** |  | 77d | 2000-12-07 A | 2001-03-23 A | 100% | 2000-12-07 | 2001-03-23 | 77d |  | N4 | 2808h | 2808h | SS7IP | Rel-4 | Kimmo | SS7IP |  |  |  |  |
| 4933 | 63.1.1 | **Stage 3 for IP Transport of CN protocols (e.g. CAP, MAP)** |  | 77d | 2000-12-07 A | 2001-03-23 A | 100% | 2000-12-07 | 2001-03-23 | 77d |  | N4 | 2192h | 2192h |  | Rel-4 | Kimmo |  |  |  |  |  |
| 4934 | 63.1.1.1 | CAP |  | 77d | 2000-12-07 A | 2001-03-23 A | 100% | 2000-12-07 | 2001-03-23 | 77d | finish no earlier than 2001-03-23 | N2 | 616h | 616h |  | Rel-4 | Kimmo |  |  |  |  |  |
| 4935 | 63.1.1.2 | MAP |  | 77d | 2000-12-07 A | 2001-03-23 A | 100% | 2000-12-07 | 2001-03-23 | 77d | finish no earlier than 2001-03-23 | N4 | 616h | 616h |  | Rel-4 | Kimmo |  |  |  |  | 29.202 |
| 4936 | 63.1.1.3 | BSSAP+ |  | 43d | 2001-01-15 A | 2001-03-14 A | 100% | 2001-01-15 | 2001-03-14 | 43d | finish no earlier than 2001-03-14 | N1 | 344h | 344h | SS7IP-BSSAP+ | Rel-4 | Frederic | SS7IP-BSSAP+ |  |  |  |  |

Notes:
- 4912: -
- 4913: -
- 4914: -
- 4915: -
- 4916: -
- 4917: Still exist? To be clarified by GERAN4/5. Marked as stopped 12/2008
- 4918: Marked as stopped 12/2008
- 4919: Marked as stopped 12/2008
- 4920: Marked as stopped 12/2008
- 4921: Marked as stopped 12/2008
- 4922: -
- 4923: Marked as stopped 12/2008
- 4924: "Joker" WI, to be used for a Rel 4 CR not related to any feature and with very limited impact on the system
- 4925: "Joker" WI, to be used for small modifications applicable to Rel 4 conformance testing. Moved in from the Stoyan/Testing WP
- 4926: -
- 4927: -
- 4928: -
- 4929: Marked as stopped 12/2008
- 4930: Marked as stopped 12/2008
- 4931: -
- 4932: -
- 4933: -
- 4934: -
- 4935: -
- 4936: -

| ID | WBS | Task | Duration | Start | Finish | Complete | Baseline start | Baseline finish | Baseline duration | Constraint | Resources | Work | Actual work | WI rapporteur name | WI rapporteur e-mail | Release | MCC resp | Acronym | Acronym_3GU_Export | Impacted TSs and TRs | TSG stopped |
| --- | --- | --- | --- | --- | --- | --- | --- | --- | --- | --- | --- | --- | --- | --- | --- | --- | --- | --- | --- | --- | --- |
| 4937 | 63.2 | **FS on Transport and control separation in the PS CN domain** | 215d | 2000-05-29 A | 2001-03-23 A | 100% | 2000-05-29 | 2001-03-23 | 215d |  | S2 | 3440h | 3440h | Ericsson | Juan-Antonio.Ibanez@eed.ericsson.se | Rel-4 | Maurice |  |  |  |  |
| 4938 | 63.2.1 | Architectural impacts | 215d | 2000-05-29 A | 2001-03-23 A | 100% | 2000-05-29 | 2001-03-23 | 215d | finish no earlier than 2001-03-23 | S2 | 1720h | 1720h |  |  | Rel-4 | Maurice |  |  |  |  |
| 4939 | 64 | **Rel-4 Improvements of Radio Interface** | 700d | 2000-07-10 A | 2003-03-14 A | 100% | 2000-07-10 | 2003-03-14 | 700d |  | RP | 28624h | 28624h |  |  | Rel-4 |  |  |  |  |  |
| 4940 | 64.1 | UTRA repeater specification (master) | 183d | 2000-07-10 A | 2001-03-21 A | 100% | 2000-07-10 | 2001-03-21 | 183d | finish no earlier than 2001-03-21 | R4 | 1464h | 1464h | Mikom, Allgon | T. Kummetz, Mikom; Alf Ahlström, Allgon | Rel-4 | Issam | RInImp-REP | RInImp-REP |  |  |
| 4941 | 64.2 | DSCH power control improvement in soft handover | 140d | 2000-09-11 A | 2001-03-23 A | 100% | 2000-09-11 | 2001-03-23 | 140d | finish no earlier than 2001-03-23 | R1 | 1120h | 1120h | Nokia | antti.toskala@nokia.com | Rel-4 | Patrick | RInImp-DSCHsho | RInImp-DSCHsho |  |  |
| 4942 | 64.3 | UMTS 1800 | 320d | 2000-09-25 A | 2001-12-14 A | 100% | 2000-09-25 | 2001-12-14 | 320d | finish no earlier than 2001-12-14 | R4 | 2560h | 2560h | Motorola | Howard Benn | Rel-4 | Issam | RInImp-UMTS18 | RInImp-UMTS18 |  |  |
| 4943 | 64.4 | UMTS 1900 | 195d | 2001-03-19 A | 2001-12-14 A | 100% | 2001-03-19 | 2001-12-14 | 195d | finish no earlier than 2001-12-14 | R4 | 1560h | 1560h | Motorola | Howard Benn | Rel-4 | Issam | RInImp-UMTS19 | RInImp-UMTS19 | 25.101 |  |
| 4944 | 64.5 | FS on High Speed downlink packet access | 155d | 2000-08-21 A | 2001-03-23 A | 100% | 2000-08-21 | 2001-03-23 | 155d | finish no earlier than 2001-03-23 | R2 | 1240h | 1240h | Motorola | Amitabha Ghosh (qa0047@email.mot.com) | Rel-4 | Yong-Jun | RInImp-HSDPA | RInImp-HSDPA |  |  |
| 4945 | 64.6 | Deleted - FS on improved common DL channel for Cell-FACH state | 340d | 2000-09-11 A | 2001-12-28 A | 100% | 2000-09-11 | 2001-12-28 | 340d | finish no earlier than 2001-12-28 | R2 | 2720h | 2720h | GBT | J. Kwak | Rel-4 | Yong-Jun | RInImp-DLCFACH | RInImp-DLCFACH |  | RP-14 |
| 4946 | 64.7 | **Conformance Test Spec. Rel-4 improvements in Radio Interface** | 375d | 2001-10-08 A | 2003-03-14 A | 100% | 2001-10-08 | 2003-03-14 | 375d |  | T1 | 12360h | 12360h |  |  | Rel-4 | Ingbert |  |  |  |  |
| 4947 | 64.7.1 | Deleted - Testing Improved usage of downlink resource in FDD for CCTrCHs of dedicated type | 140d | 2002-02-18 A | 2002-08-30 A | 100% | 2002-02-18 | 2002-08-30 | 140d | finish no earlier than 2002-08-30 | T1 | 1120h | 1120h |  |  | Rel-4 | Ingbert |  |  |  | TP-17 |
| 4948 | 64.7.2 | Deleted - Testing Terminal Power saving features | 140d | 2002-02-18 A | 2002-08-30 A | 100% | 2002-02-18 | 2002-08-30 | 140d | finish no earlier than 2002-08-30 | T1 | 1120h | 1120h |  |  | Rel-4 | Ingbert |  |  |  | TP-17 |
| 4949 | 64.7.3 | Deleted - Testing DSCH power control improvement in soft handover | 140d | 2002-02-18 A | 2002-08-30 A | 100% | 2002-02-18 | 2002-08-30 | 140d | finish no earlier than 2002-08-30 | T1 | 1120h | 1120h |  |  | Rel-4 | Ingbert |  |  |  | TP-17 |
| 4950 | 64.7.4 | Testing UMTS 1800 | 180d | 2001-10-08 A | 2002-06-14 A | 100% | 2001-10-08 | 2002-06-14 | 180d | finish no earlier than 2002-06-14 | T1 | 1440h | 1440h |  |  | Rel-4 | Ingbert |  |  | 34.108, 34,121, 34.122, 34.123-1 |  |
| 4951 | 64.7.5 | Testing UMTS 1900 | 180d | 2001-10-08 A | 2002-06-14 A | 100% | 2001-10-08 | 2002-06-14 | 180d | finish no earlier than 2002-06-14 | T1 | 1440h | 1440h |  |  | Rel-4 | Ingbert |  |  | 34.108, 34,121, 34.122, 34.123-1 |  |
| 4952 | 64.7.6 | Testing UMTS 1800 - TTCN | 195d | 2002-06-17 A | 2003-03-14 A | 100% | 2002-06-17 | 2003-03-14 | 195d | finish no earlier than 2003-03-14 | T1 | 1560h | 1560h |  |  | Rel-4 | Ingbert |  |  | 34.123-3 |  |
| 4953 | 64.7.7 | Testing UMTS 1900 - TTCN | 195d | 2002-06-17 A | 2003-03-14 A | 100% | 2002-06-17 | 2003-03-14 | 195d | finish no earlier than 2003-03-14 | T1 | 1560h | 1560h |  |  | Rel-4 | Ingbert |  |  | 34.123-3 |  |
| 4954 | 65 | **Rel-4 RAN improvements** | 938d? | 2000-08-14 A | 2004-03-17 A | 100% | 2000-08-14 | 2004-03-17 | 938d? |  | RP | 29336h | 29336h |  |  | Rel-4 |  |  |  |  |  |
| 4955 | 65.1 | Node B synchronization for TDD | 160d | 2000-08-14 A | 2001-03-23 A | 100% | 2000-08-14 | 2001-03-23 | 160d | finish no earlier than 2001-03-23 | R1 | 1280h | 1280h | Siemens | S. Oestreich | Rel-4 | Patrick | RANimp-NBsync | RANimp-NBsync |  |  |
| 4956 | 65.2 | RAB support enhancement for Rel-4 | 155d | 2000-08-21 A | 2001-03-23 A | 100% | 2000-08-21 | 2001-03-23 | 155d | finish no earlier than 2001-03-23 | R2 | 1240h | 1240h | Ericsson | M. Israelsson, A. Krishnarajah | Rel-4 | Yong-Jun | RANimp-RABSE | RANimp-RABSE |  |  |
| 4957 | 65.4 | **Deleted - Conformance Test Aspects - Rel-4 RAN Improvements** | 577d? | 2002-01-01 A | 2004-03-17 A | 100% | 2002-01-01 | 2004-03-17 | 577d? |  | T1 | 19312h | 19312h |  |  | Rel-4 | Ingbert |  |  |  | TP-23 |
| 4958 | 65.4.1 | Deleted - Testing Radio access bearer support enhancments | 175d | 2002-01-01 A | 2002-09-02 A | 100% | 2002-01-01 | 2002-09-02 | 175d | finish no earlier than 2002-09-02 | T1 | 1400h | 1400h |  |  | Rel-4 | Ingbert |  |  |  | TP-17 |
| 4959 | 65.4.2 | Deleted - Testing RAB support enhancements-Robust Header Compression | 332d | 2002-05-28 A | 2003-09-03 A | 100% | 2002-05-28 | 2003-09-03 | 332d | finish no earlier than 2003-09-03 | T1 | 2656h | 2656h |  |  | Rel-4 | Ingbert | RABimp-RoCH | RABimp-RoCH | 34.123-1, -2 | TP-21 |
| 4960 | 65.4.3 | Deleted - Testing RAB support enhancements-Robust Header Compression - TTCN | 472d | 2002-05-28 A | 2004-03-17 A | 100% | 2002-05-28 | 2004-03-17 | 472d | finish no earlier than 2004-03-17 | T1 | 3776h | 3776h |  |  | Rel-4 | Ingbert |  |  | 34.123-3 | TP-23 |
| 4961 | 65.4.4 | Testing of Extended Robut Header Compression | 270d | 2002-09-18 A | 2003-09-30 A | 100% | 2002-09-18 | 2003-09-30 | 270d | finish no earlier than 2003-09-30 | T1 | 2160h | 2160h |  |  | Rel-4 | Ingbert | Ext-RoHC | Ext-RoHC | 34.123-1, -2 |  |
| 4962 | 65.4.5 | Deleted - Testing of Extended Robut Header Compression - TTCN | 325d | 2002-09-18 A | 2003-12-16 A | 100% | 2002-09-18 | 2003-12-16 | 325d | finish no earlier than 2003-12-16 | T1 | 2600h | 2600h |  |  | Rel-4 | Ingbert |  |  | 34.123-3 | TP-22 |
| 4963 | 1159.3.6 | Deleted - General changes to TS34.121 corresponding to release 4 | 263d? | 2003-03-03 A | 2004-03-03 A | 100% | 2003-03-03 | 2004-03-03 | 263d? | finish no earlier than 2004-03-03 | T1 | 2104h | 2104h |  |  | Rel-4 | Ingbert | RANimp-test, TEI4 | RANimp-test, TEI4 | 34.108, 34.121 | TP-23 |

Notes:
- 4937: -
- 4938: -
- 4939: -
- 4940: -
- 4941: -
- 4942: -
- 4943: -
- 4944: -
- 4945: Stopped at RP#14
- 4946: -
- 4947: Marked as stopped 12/2008
- 4948: Marked as stopped 12/2008
- 4949: Marked as stopped 12/2008
- 4950: -
- 4951: -
- 4952: -
- 4953: -
- 4954: -
- 4955: -
- 4956: 29 Nov 2000: split into ROHC and non-ROHC part; 5 Mar 2001: splitting off of ROHC for Rel-4 agreed by R2
- 4957: Marked as stopped 12/2008
- 4958: Marked as stopped 12/2008
- 4959: UID changed. Marked as stopped 12/2008
- 4960: UID changed. Marked as stopped 12/2008
- 4961: Marked as closed 12/2008 (was marked 15% complete)
- 4962: Marked as stopped 12/2008
- 4963: Marked as stopped 12/2008

| ID | WBS | Task | Duration | Start | Finish | Complete | Baseline start | Baseline finish | Baseline duration | Constraint | Resources | Work | Actual work | Acronym | WI rapporteur name | Release | MCC resp | Special Focus Doc | Acronym_3GU_Export | TSG stopped | WI rapporteur e-mail | Status Report |
| --- | --- | --- | --- | --- | --- | --- | --- | --- | --- | --- | --- | --- | --- | --- | --- | --- | --- | --- | --- | --- | --- | --- |
| 4964 | 66 | **Rel-4 Emergency call enhancements** | 628d | 2000-01-03 A | 2002-05-28 A | 100% | 2000-01-03 | 2002-05-28 | 628d |  | N1; S1; T1 | 18672h | 18672h | EMC1-CS | Ericsson | Rel-4 | Frederic | Public Safety (I-A) | EMC1, EMC1-CS |  |  |  |
| 4965 | 66.1 | **For CS based calls** | 628d | 2000-01-03 A | 2002-05-28 A | 100% | 2000-01-03 | 2002-05-28 | 628d |  | N1 | 3600h | 3600h | EMC1-CS | Ericsson | Rel-4 | Frederic | Public Safety (I-A) | EMC1-CS |  |  |  |
| 4966 | 66.1.1 | Distinction in CS domain of emergency call types to different emergency services | 40d | 2000-05-01 A | 2000-06-23 A | 100% | 2000-05-01 | 2000-06-23 | 40d | finish no earlier than 2000-06-23 | S1 | 320h | 320h |  |  | Rel-4 | Alain | Public Safety (I-A) |  |  |  |  |
| 4967 | 66.1.2 | Distinction in CS domain of emergency calls to different emergency types | 22d | 2000-08-24 A | 2000-09-22 A | 100% | 2000-08-24 | 2000-09-22 | 22d | finish no earlier than 2000-09-22 | N1 | 176h | 176h |  |  | Rel-4 | Frederic | Public Safety (I-A) |  |  |  |  |
| 4968 | 66.1.3 | Deleted - Conformance Test Aspects - Emergency call enhancements | 151d | 2000-01-03 A | 2000-07-28 A | 100% | 2000-01-03 | 2000-07-28 | 151d |  | T1 | 1200h | 1200h |  |  | Rel-4 | Ingbert | Public Safety (I-A) |  | TP-08 |  |  |
| 4969 | 66.1.4 | Testing CS based emergency calls | 67d | 2002-02-25 A | 2002-05-28 A | 100% | 2002-02-25 | 2002-05-28 | 67d | finish no earlier than 2002-05-28 | T1 | 536h | 536h |  |  | Rel-4 | Ingbert | Public Safety (I-A) |  |  |  |  |
| 4970 | 66.1.5 | Testing CS based emergency calls - TTCN | 134d | 2001-11-22 A | 2002-05-28 A | 100% | 2001-11-22 | 2002-05-28 | 134d | finish no earlier than 2002-05-28 | T1 | 1072h | 1072h |  |  | Rel-4 | Ingbert | Public Safety (I-A) |  |  |  |  |
| 4971 | 67 | **Rel-4 Terminal interfaces** | 315d | 2000-01-03 A | 2001-03-15 A | 100% | 2000-01-03 | 2001-03-15 | 315d |  | T2 | 14296h | 14296h | TI |  | Rel-4 | Kimmo |  | TI |  |  |  |
| 4972 | 67.1 | **AT commands enhancements** | 314d | 2000-01-03 A | 2001-03-14 A | 100% | 2000-01-03 | 2001-03-14 | 314d |  | T2 | 5016h | 5016h | TI-ATC |  | Rel-4 | Kimmo |  | TI-ATC |  |  |  |
| 4973 | 67.1.1 | Specification of AT commands for new services | 314d | 2000-01-03 A | 2001-03-14 A | 100% | 2000-01-03 | 2001-03-14 | 314d | finish no earlier than 2001-03-14 | T2 | 2504h | 2504h |  |  | Rel-4 | Kimmo |  |  |  |  |  |
| 4974 | 67.2 | **Wide Area Data Synchronization** | 314d | 2000-01-03 A | 2001-03-14 A | 100% | 2000-01-03 | 2001-03-14 | 314d |  | T2 | 5016h | 5016h | TI-WADS |  | Rel-4 | Kimmo |  | TI-WADS |  |  |  |
| 4975 | 67.2.1 | Continues evolution of Synchronization protocol | 314d | 2000-01-03 A | 2001-03-14 A | 100% | 2000-01-03 | 2001-03-14 | 314d | finish no earlier than 2001-03-14 | T2 | 2504h | 2504h | TI-SYNC-EVOL |  | Rel-4 | Kimmo |  | TI-SYNC-EVOL |  |  |  |
| 4976 | 67.3 | Terminal local model | 218d | 2000-05-16 A | 2001-03-15 A | 100% | 2000-05-16 | 2001-03-15 | 218d | finish no earlier than 2001-03-15 | T2 | 1744h | 1744h | TLM | Ericsson | Rel-4 | Kimmo |  | TLM |  | Olga.Tome@ECS.ERICSSON.SE |  |
| 4977 | 68 | **Rel-4 Location Services enhancements** | 455d | 2000-04-03 A | 2001-12-28 A | 100% | 2000-04-03 | 2001-12-28 | 455d |  | S2; S1; T2; N1; N4; R3; R2 | 67671.2h | 67671.2h | LCS4 | Nokia | Rel-4 | Maurice |  | LCS1 |  | Jan Kall |  |
| 4978 | 68.1 | CBS interactions | 455d | 2000-04-03 A | 2001-12-28 A | 100% | 2000-04-03 | 2001-12-28 | 455d | finish no earlier than 2001-12-28 | T2 | 3640h | 3640h | LCS4-CBS |  | Rel-4 |  |  | LCS1-CBS |  |  |  |
| 4979 | 68.2 | LCS support in the CS domain | 180d | 2000-05-15 A | 2001-01-19 A | 100% | 2000-05-15 | 2001-01-19 | 180d | finish no earlier than 2001-01-19 | S2 | 1440h | 1440h | LCS4-CS |  | Rel-4 | Maurice |  | LCS1-CS |  |  |  |
| 4980 | 68.3 | **LCS support in the PS domain** | 435d | 2000-05-01 A | 2001-12-28 A | 100% | 2000-05-01 | 2001-12-28 | 435d |  | S2; S1; N1; N4 | 29880h | 29880h | LCS4-PS |  | Rel-4 | Maurice |  | LCS1-PS |  |  |  |
| 4981 | 68.3.1 | Stage 1 for LCS support in the PS domain | 40d | 2000-07-03 A | 2000-08-25 A | 100% | 2000-07-03 | 2000-08-25 | 40d | start no earlier than 2000-07-03 | S1 | 320h | 320h |  | Pacific Bell Wireless | Rel-4 | Alain |  |  |  | Randolph Wohlert (rwohlert@tri.sbc.com) |  |
| 4982 | 68.3.2 | Stage 2 for LCS support in the PS domain | 190d | 2000-05-01 A | 2001-01-19 A | 100% | 2000-05-01 | 2001-01-19 | 190d | finish no earlier than 2001-01-19 | S2; R2; G1 | 4560h | 4560h |  |  | Rel-4 | Maurice |  |  |  |  |  |
| 4983 | 68.3.3 | **Stage 3 for LCS support in the PS domain** | 355d | 2000-08-21 A | 2001-12-28 A | 100% | 2000-08-21 | 2001-12-28 | 355d |  | N1; N4 | 11080h | 11080h |  |  | Rel-4 | Frederic |  |  |  |  |  |
| 4984 | 68.3.3.1 | Layer 3 LCS signalling UE (MS) -SGSN (UMTS PS and and GSM-GPRS) | 355d | 2000-08-21 A | 2001-12-28 A | 100% | 2000-08-21 | 2001-12-28 | 355d | finish no earlier than 2001-12-28 | N1 | 2840h | 2840h |  | Nokia | Rel-4 | Frederic |  |  |  | Janne Muhonen |  |
| 4985 | 68.3.3.2 | MAP impacts of LCS | 160d | 2000-08-21 A | 2001-03-30 A | 100% | 2000-08-21 | 2001-03-30 | 160d | finish no earlier than 2001-03-30 | N4 | 1280h | 1280h |  |  | Rel-4 | Kimmo |  |  |  |  |  |
| 4986 | 68.3.3.3 | GTP signalling for LCS | 160d | 2000-08-21 A | 2001-03-30 A | 100% | 2000-08-21 | 2001-03-30 | 160d | finish no earlier than 2001-03-30 | N4 | 1280h | 1280h |  |  | Rel-4 | Kimmo |  |  |  |  |  |
| 4987 | 68.4 | **UE positioning Rel-4** | 260d | 2000-04-03 A | 2001-03-30 A | 100% | 2000-04-03 | 2001-03-30 | 260d |  | R3; R2 | 7231.2h | 7231.2h | LCS1-UEpos |  | Rel-4 | Issam |  | LCS1-UEpos |  |  | RP-010045 |
| 4988 | 68.4.1 | Iub/Iur interfaces for methods Rel 99 | 233.9d | 2000-04-03 A | 2001-03-30 A | 100% | 2000-04-03 | 2001-03-30 | 233.9d | finish no earlier than 2001-03-30 | R3 | 1871.2h | 1871.2h | LCS1-UEpos-IubIur | Ericsson | Rel-4 | Juha |  | LCS1-UEpos-IubIur |  | Yun-Chao Hu | RP-010045 |
| 4989 | 68.4.2 | UE positioning enhancements - IPDL for TDD | 150d | 2000-08-28 A | 2001-03-23 A | 100% | 2000-08-28 | 2001-03-23 | 150d | finish no earlier than 2001-03-23 | R2 | 1200h | 1200h | LCS1-UEpos-enh | Siemens | Rel-4 | Yong-Jun |  | LCS1-UEpos-enh |  | Armin Sitte | RP-010045 |

Notes:
- 4964: Acronym changed from EMC1, EMC1-CS
- 4965: WI approved in TSG_10
- 4966: -
- 4967: Calls to different emergency services such as ambulance, fire brigade, police, etc. can be routed to respective different emergency centres. / NP-000447 is the stage 3 changes for CS call control protocol. / Impacted TSs and TRs: 24.008
- 4968: UID changed. Marked as stopped 12/2008
- 4969: - / Impacted TSs and TRs: 34.123-1
- 4970: - / Impacted TSs and TRs: 34.123-3
- 4971: -
- 4972: - / Impacted TSs and TRs: 27.007
- 4973: goal not completely achieved because of missing input / Impacted TSs and TRs: 27.007
- 4974: AS: Rel5 changed to Rel4 according to SP#10 decision, milestone on testing added
- 4975: - / Impacted TSs and TRs: 27.903, 27.103
- 4976: - / Impacted TSs and TRs: 23.227
- 4977: Acronym changed form LCS1
- 4978: - / Impacted TSs and TRs: 23.041
- 4979: Only MAP impact foreseen so far. To be further split if needed.
- 4980: -
- 4981: To be also considered: External LCS client identity, and Privacy options when PDP-context and when no PDP-context is established / Impacted TSs and TRs: 22.071
- 4982: SP#10 completed / Impacted TSs and TRs: 25.305 (UTRAN part), new 23.271 (CN part by S2, 43.059 (GERAN part)
- 4983: -
- 4984: -
- 4985: -
- 4986: -
- 4987: -
- 4988: - / Impacted TSs and TRs: 25.401, 25.420, 25.423, 25.430, 25.433, new TR 25.850
- 4989: 5 Mar 2001: split of IPDL for TDD agreed by R2 / Impacted TSs and TRs: new TR 25.847

| ID | WBS | Task | Duration | Start | Finish | Complete | Baseline start | Baseline finish | Baseline duration | Constraint | Resources | Work | Actual work | Acronym | Release | MCC resp | Acronym_3GU_Export | Impacted TSs and TRs | WI rapporteur name | WI rapporteur e-mail | TSG stopped |
| --- | --- | --- | --- | --- | --- | --- | --- | --- | --- | --- | --- | --- | --- | --- | --- | --- | --- | --- | --- | --- | --- |
| 4990 | 69 | **Rel-4 UICC/(U)SIM enhancements and interworking** | 175d | 2000-07-24 A | 2001-03-23 A | 100% | 2000-07-24 | 2001-03-23 | 175d |  | T3 | 2800h | 2800h | UICC1 | Rel-4 | Xavier | UICC1, Rel-4 |  |  |  |  |
| 4991 | 69.1 | Common PCN Handset Specification (CPHS) | 175d | 2000-07-24 A | 2001-03-23 A | 100% | 2000-07-24 | 2001-03-23 | 175d | finish no earlier than 2001-03-23 | T3 | 1400h | 1400h | UICC1-CPHS | Rel-4 | Xavier | UICC1-CPHS | 27.103 | One2One |  |  |
| 4992 | 70 | **Rel-4 (U)SIM toolkit enhancements** | 210d | 2000-06-05 A | 2001-03-23 A | 100% | 2000-06-05 | 2001-03-23 | 210d |  | T3; S1 | 6720h | 6720h | USAT4 | Rel-4 | Xavier | USAT1, USAT1-LocLnk, USAT1APIJAVA, USAT1SM | 23.048 (USAT1SM), 43.019 (USAT1APIJAVA) | Gemplus | Jean-Francois Rubon |  |
| 4993 | 70.1 | USAT local link | 210d | 2000-06-05 A | 2001-03-23 A | 100% | 2000-06-05 | 2001-03-23 | 210d | finish no earlier than 2001-03-23 | T3; S1 | 3360h | 3360h | USAT1-LocLnk | Rel-4 | Xavier | USAT1-LocLnk | 22.038, 31.111 | Gemplus | Jean-Francois Rubon |  |
| 4994 | 71 | **Rel-4 Security enhancements** | 576d | 2000-01-03 A | 2002-03-15 A | 100% | 2000-01-03 | 2002-03-15 | 576d |  | S3; N4; N1 | 38112h | 38112h | SEC4 | Rel-4 | Mirko | SEC1 |  | Vodafone | Peter.Howard@vodafone.com |  |
| 4995 | 54.2 | Rel-4 Lawful Interception | 155d | 2000-08-21 A | 2001-03-23 A | 100% | 2000-08-21 | 2001-03-23 | 155d | finish no earlier than 2001-03-23 | S3 | 1240h | 1240h | SEC4-LI | Rel-4 | Mirko | SEC1-LI | 33.107 |  |  |  |
| 4996 | 71.1 | Evolution of GSM CS algorithms (e.g. A5/3 development and deployment) | 272d | 2000-01-03 A | 2001-01-15 A | 100% | 2000-01-03 | 2001-01-15 | 272d | finish no earlier than 2001-01-15 | S3 | 2168h | 2168h | SEC1-CSALGO1 | Rel-4 | Mirko | SEC1-CSALGO1 | 33.102, 33.103, 33.105 | DTI, BIS | cbrookson@iee.org |  |
| 4997 | 71.2 | **Evolution of GSM PS algorithms (e.g. GEA 2 deployment)** | 219d | 2000-02-22 A | 2000-12-22 A | 100% | 2000-02-22 | 2000-12-22 | 219d |  | S3; N4; N1 | 9528h | 9528h | SEC1-PSALGO1 | Rel-4 | Mirko | SEC1-PSALGO1 | 33.102, 33.103, 33.105 | DTI, BIS | cbrookson@iee.org |  |
| 4998 | 71.2.1 | Deleted - Main aspects of Evolution of GSM PS algorithms (e.g. GEA 2 deployment) | 199d | 2000-02-22 A | 2000-11-24 A | 100% | 2000-02-22 | 2000-11-24 | 199d | finish no earlier than 2000-11-24 | S3 | 1592h | 1592h |  | Rel-4 | Mirko |  |  | DTI, BIS | cbrookson@iee.org | SP-69 |
| 4999 | 71.2.2 | Impact on GTP | 200d | 2000-03-20 A | 2000-12-22 A | 100% | 2000-03-20 | 2000-12-22 | 200d | finish no earlier than 2000-12-22 | N4 | 1600h | 1600h |  | Rel-4 | Kimmo |  |  | DTI, BIS | cbrookson@iee.org |  |
| 5000 | 71.2.3 | GEA capability indication in MS CM | 135d | 2000-06-19 A | 2000-12-22 A | 100% | 2000-06-19 | 2000-12-22 | 135d | finish no earlier than 2000-12-22 | N1 | 1080h | 1080h | SEC1-PSALGO1-GEACAP | Rel-4 | Frederic | SEC1-PSALGO1-GEACAP |  | Vodafone Airtouch | Duncan Mills |  |
| 5001 | 71.3 | **Deleted - MAP application layer security** | 576d | 2000-01-03 A | 2002-03-15 A | 100% | 2000-01-03 | 2002-03-15 | 576d |  | S3 | 11352h | 11352h | SEC1-MAPAL | Rel-4 | Mirko | SEC1-MAPAL |  |  |  | SP-15 |
| 5002 | 71.3.1 | Deleted - Main aspects of MAP application layer security | 199d | 2000-02-21 A | 2001-03-29 A | 100% | 2000-02-21 | 2001-03-29 | 199d | start no earlier than 2000-02-21 | S3 | 1592h | 1592h |  | Rel-4 | Mirko |  |  |  |  | SP-11 |
| 5003 | 71.3.2 | Deleted - Other stage 3 aspects | 199d | 2000-02-22 A | 2000-11-24 A | 100% | 2000-02-22 | 2000-11-24 | 199d | finish no earlier than 2000-11-24 | N4 | 1592h | 1592h |  | Rel-4 | Kimmo |  |  |  |  | CP-10 |
| 5004 | 71.3.3 | Deleted - Visibility and Configurability of security | 576d | 2000-01-03 A | 2002-03-15 A | 100% | 2000-01-03 | 2002-03-15 | 576d | finish no earlier than 2002-03-15 | S3 | 4600h | 4600h | SEC1-VCS | Rel-4 | Mirko | SEC1-VCS |  | France Telecom | Sebastien.nguyenngoc@rd.francetelecom.com | SP-15 |
| 5005 | 72 | **Rel-4 Charging and OAM&P** | 221d | 2000-12-01 A | 2001-10-05 A | 100% | 2000-12-01 | 2001-10-05 | 221d |  | S5 | 10472h | 10472h | OAM4 | Rel-4 | Mirko | OAM4 |  |  |  |  |
| 5006 | 72.1 | Rel-4 Principles, high level Requirements and Architecture | 145d | 2000-12-01 A | 2001-06-21 A | 100% | 2000-12-01 | 2001-06-21 | 145d | finish no earlier than 2001-06-21 | S5 | 1160h | 1160h |  | Rel-4 | Mirko |  | 32.101, 32.102 | Motorola, Telia | Michael.Truss@motorola.com, Tommy.R.Berggren@TELIA.SE |  |
| 5007 | 72.2 | Rel-4 Performance Management | 216d | 2000-12-01 A | 2001-09-28 A | 100% | 2000-12-01 | 2001-09-28 | 216d | finish no earlier than 2001-06-21 | S5 | 1728h | 1728h |  | Rel-4 | Mirko |  | 32.4xy, 52.402 | T-Mobile | karl-heinz.nenner@t-mobile.de |  |
| 5008 | 72.3 | Fault Management | 221d | 2000-12-01 A | 2001-10-05 A | 100% | 2000-12-01 | 2001-10-05 | 221d | finish no earlier than 2001-06-21 | S5 | 1768h | 1768h |  | Rel-4 | Mirko |  | 32.111-1/4 | Lucent |  |  |
| 5009 | 72.4 | Configuration Management | 145d | 2000-12-01 A | 2001-06-21 A | 100% | 2000-12-01 | 2001-06-21 | 145d | finish no earlier than 2001-06-21 | S5 | 1160h | 1160h |  | Rel-4 | Mirko |  | 32.106-1/8 | Ericsson | thomas.tovinger@ericsson.com |  |
| 5010 | 72.5 | Rel-4 Charging Management | 216d | 2000-12-01 A | 2001-09-28 A | 100% | 2000-12-01 | 2001-09-28 | 216d | finish no earlier than 2001-06-21 | S5 | 1728h | 1728h |  | Rel-4 | Mirko |  | 32.200, 32.205, 32.215, 32.235 | T-Mobile | karl-heinz.nenner@t-mobile.de |  |
| 5011 | 72.6 | UTRAN Operations and Maintenance procedures | 145d | 2000-12-01 A | 2001-06-21 A | 100% | 2000-12-01 | 2001-06-21 | 145d | finish no earlier than 2001-06-21 | S5 | 1160h | 1160h | UOAM | Rel-4 | Mirko | UOAM | 32.800 | Mannesmann Mobilfunk | bert.boden@d2mannesmann.de |  |
| 5012 | 73 | **Global Text Telephony** | 317d? | 2000-01-03 A | 2001-03-19 A | 100% | 2000-01-03 | 2009-09-18 | 2537d? |  | S1; S2; S4; T1; R5 | 18528h | 18528h | GTT | Rel-4 | Maurice | GTT |  | Ericsson | gunnar.hellstrom@omnitor.se |  |
| 5013 | 73.1 | Stage 1 for Global Text Telephony | 188d | 2000-04-05 A | 2000-12-22 A | 100% | 2000-04-05 | 2000-12-22 | 188d | finish no earlier than 2000-12-22 | S1 | 1504h | 1504h |  | Rel-4 | Alain |  | 22.226 |  |  |  |
| 5014 | 73.2 | Stage 2 for Global Text Telephony | 206d | 2000-01-03 A | 2000-10-13 A | 100% | 2000-01-03 | 2000-10-13 | 206d |  | S2 | 1640h | 1640h |  | Rel-4 | Maurice |  | 23.226 |  |  |  |

Notes:
- 4990: Acronym changed from UICC1, Rel-4
- 4991: 28/5/2001: CRs approved at TP-11. WI complete.
- 4992: Acronym changed from USAT1, USAT1-LocLnk, USAT1APIJAVA, USAT1SM
- 4993: 25/5/2001:CR was approved at TP-11. WI is complete
- 4994: acronym changed from SEC1
- 4995: Requirements capture: S3#14 (Aug 00), Feature specification: S3#15 (Sep 00), Definition of architecture. Should be included in general LI work mentioned above.. Acronym changed from SEC1-LI
- 4996: SP#8 approved WID
- 4997: SP#8 approved WID
- 4998: Complete TSG#09 (09/2000). S3#17: Proposed for deletion. TO BE DELETED
- 4999: -
- 5000: -
- 5001: REPLACED BY NDS-MAP and NDS-IP. Completed Auto Key Management -> Rel-6. Marked as stopped 12/2008
- 5002: UID changed. Marked as stopped 12/2008
- 5003: UID changed. Marked as stopped 12/2008
- 5004: CR approved at SA3#21 awaiting comments from CN1. Marked as stopped 12/2008
- 5005: SP#13 approved WID
- 5006: -
- 5007: -
- 5008: -
- 5009: -
- 5010: -
- 5011: -
- 5012: SP#12 updated WID SP-000162=>SP-010340
- 5013: -
- 5014: -

| ID | WBS | Task | Type | Duration | Start | Finish | Complete | Baseline start | Baseline finish | Baseline duration | Constraint | Resources | Work | Actual work | Acronym | Release | MCC resp | Acronym_3GU_Export | PCG stopped | TSG stopped |
| --- | --- | --- | --- | --- | --- | --- | --- | --- | --- | --- | --- | --- | --- | --- | --- | --- | --- | --- | --- | --- |
| 5015 | 73.3 | **Specification of Cellular Text telephone Modem** |  | 136d | 2000-09-11 A | 2001-03-19 A | 100% | 2000-09-11 | 2001-03-19 | 136d |  | S4 | 2704h | 2704h | GTT-CTM | Rel-4 | Paolo | GTT-CTM |  |  |
| 5016 | 73.3.1 | General description and C-code |  | 66d | 2000-09-11 A | 2000-12-11 A | 100% | 2000-09-11 | 2000-12-11 | 66d | finish no earlier than 2000-12-11 | S4 | 528h | 528h |  | Rel-4 | Paolo |  |  |  |
| 5017 | 73.3.2 | Minimum Performance requirements |  | 136d | 2000-09-11 A | 2001-03-19 A | 100% | 2000-09-11 | 2001-03-19 | 136d | finish no earlier than 2001-03-19 | S4 | 1088h | 1088h |  | Rel-4 | Paolo |  |  |  |
| 5018 | 73.5 | Deleted - Conformance Test Aspects - Global Text Telephony | milestone | 0d? | 2000-09-21 A | 2000-09-21 A | 100% | 2000-09-21 | 2009-09-18 | 2348d? | finish no earlier than 2009-09-18 | R5; T1 |  |  | GTT_Test | Rel-4 | Ingbert | GTT_Test | PCG-23 | RP-45 |
| 5019 | 1168 | Release 1999 Features |  | 261d? | 2000-01-03 A | 2000-12-29 A | 100% | 2000-01-03 | 2000-12-29 | 261d? |  | NP; SP; TP; SMG | 8352h | 8352h |  | R99 | All |  |  |  |
| 5020 | 1169 | **UMTS Features** |  | 261d? | 1999-01-01 A | 1999-12-31 A | 100% | 1999-01-01 | 1999-12-31 | 261d? |  | S1; S2; S4; SMG; N3; N4; RP | 39672h | 39672h |  | R99 | Alain |  |  |  |
| 5021 | 1169.1 | UMTS_SERVICES |  | 261d? | 1999-01-01 A | 1999-12-31 A | 100% | 1999-01-01 | 1999-12-31 | 261d? | start no earlier than 1999-01-01 | S1 | 2088h | 2088h | UMTS_SERVICES | R99 | Alain | UMTS_SERVICES |  |  |
| 5022 | 1169.2 | UMTS phase 1 |  | 261d? | 1999-01-01 A | 1999-12-31 A | 100% | 1999-01-01 | 1999-12-31 | 261d? | start no earlier than 1999-01-01 | S1 | 2088h | 2088h | UMTS1 | R99 | Alain | UMTS1 |  |  |
| 5023 | 1169.3 | UMTS Capabilities |  | 261d? | 1999-01-01 A | 1999-12-31 A | 100% | 1999-01-01 | 1999-12-31 | 261d? | start no earlier than 1999-01-01 | S1 | 2088h | 2088h | UMTS_Capabil | R99 | Alain | UMTS_Capabil |  |  |
| 5024 | 1169.4 | Architecture of the GSM-UMTS platform |  | 261d? | 1999-01-01 A | 1999-12-31 A | 100% | 1999-01-01 | 1999-12-31 | 261d? | start no earlier than 1999-01-01 | S2; N4 | 4176h | 4176h |  | R99 | Maurice |  |  |  |
| 5025 | 1169.5 | UMTS Terrestrial Radio Access Network |  | 261d? | 1999-01-01 A | 1999-12-31 A | 100% | 1999-01-01 | 1999-12-31 | 261d? | start no earlier than 1999-01-01 | RP | 2088h | 2088h | UTRAN | R99 | Yong-Jun | UTRAN |  |  |
| 5026 | 1169.6 | UMTS 1800, UMTS 1900 |  | 261d? | 1999-01-01 A | 1999-12-31 A | 100% | 1999-01-01 | 1999-12-31 | 261d? | start no earlier than 1999-01-01 | R2 | 2088h | 2088h | Rlnlmp19, Rlnlmp18 | R99 | Yong-Jun | Rlnlmp19, Rlnlmp18 |  |  |
| 5027 | 1169.7 | Mandatory speech codec for narrowband telephony service |  | 261d? | 1999-01-01 A | 1999-12-31 A | 100% | 1999-01-01 | 1999-12-31 | 261d? | start no earlier than 1999-01-01 | S4 | 2088h | 2088h | Mandatory_Speech_Codec, AMR-NB, AMR | R99 | Paolo | Mandatory_Speech_Codec, AMR-NB, AMR |  |  |
| 5028 | 1169.8 | Codec for low bitrate multimedia telephony service |  | 261d? | 1999-01-01 A | 1999-12-31 A | 100% | 1999-01-01 | 1999-12-31 | 261d? | start no earlier than 1999-01-01 | S4 | 2088h | 2088h | Low_bit_rate_codec_for_MM_Tel., H.324M | R99 | Paolo | Low_bit_rate_codec_for_MM_Tel., H.324M |  |  |
| 5029 | 1169.9 | 3G Audio-Visual Terminal characteristics |  | 261d? | 1999-01-01 A | 1999-12-31 A | 100% | 1999-01-01 | 1999-12-31 | 261d? | start no earlier than 1999-01-01 | S4 | 2088h | 2088h | WI5TAC, 3G-AVT, Terminal_Acoustic_Characteristics | R99 | Paolo | WI5TAC, 3G-AVT, Terminal_Acoustic_Characteristics |  |  |
| 5030 | 1169.10 | Updates_for_UMTS |  | 261d? | 1999-01-01 A | 1999-12-31 A | 100% | 1999-01-01 | 1999-12-31 | 261d? | start no earlier than 1999-01-01 | N3 | 2088h | 2088h | Updates_for_UMTS | R99 | Gwiho | Updates_for_UMTS |  |  |
| 5031 | 1169.11 | UMTS |  | 261d? | 1999-01-01 A | 1999-12-31 A | 100% | 1999-01-01 | 1999-12-31 | 261d? | start no earlier than 1999-01-01 | N3 | 2088h | 2088h | UMTS | R99 | Gwiho | UMTS |  |  |
| 5032 | 1170 | **UMTS and GSM Features** |  | 261d? | 1999-01-01 A | 1999-12-31 A | 100% | 1999-01-01 | 1999-12-31 | 261d? |  | S1; S2; SMG; T2; N1; N2; N3; N4; R2; R3 | 219240h | 219240h |  | R99 | Alain |  |  |  |
| 5033 | 1170.1 | Multimedia Messaging Service |  | 261d? | 1999-01-01 A | 1999-12-31 A | 100% | 1999-01-01 | 1999-12-31 | 261d? | start no earlier than 1999-01-01 | T2 | 2088h | 2088h | MMS | R99 |  | MMS |  |  |
| 5034 | 1170.2 | Location Services |  | 261d? | 1999-01-01 A | 1999-12-31 A | 100% | 1999-01-01 | 1999-12-31 | 261d? | start no earlier than 1999-01-01 | S1; S2; S3; SMG1; SMG2; SMG12; N1; N2; N4; R2; R3 | 22968h | 22968h | LCS | R99 | Alain | LCS |  |  |
| 5035 | 1170.3 | **Customised Application for Mobile network Enhanced Logic Phase 3** |  | 261d? | 1999-01-01 A | 1999-12-31 A | 100% | 1999-01-01 | 1999-12-31 | 261d? |  | S1; S2; N2; N4 | 18792h | 18792h | CAMEL3 | R99 | Alain | CAMEL3 |  |  |
| 5036 | 1170.3.1 | Global view |  | 261d? | 1999-01-01 A | 1999-12-31 A | 100% | 1999-01-01 | 1999-12-31 | 261d? | start no earlier than 1999-01-01 | S1; S2; N2; N4 | 8352h | 8352h |  | R99 | Alain |  |  |  |
| 5037 | 1170.3.2 | Multiple Subscriber Profile (MSP) based on CAMEL phase 3 |  | 261d? | 1999-01-01 A | 1999-12-31 A | 100% | 1999-01-01 | 1999-12-31 | 261d? | start no earlier than 1999-01-01 | S1 | 2088h | 2088h |  | R99 | Alain |  |  |  |
| 5038 | 1170.4 | Short Message Service enhancements / Enhanced Messaging Service (EMS) |  | 261d? | 1999-01-01 A | 1999-12-31 A | 100% | 1999-01-01 | 1999-12-31 | 261d? | start no earlier than 1999-01-01 | T2 | 2088h | 2088h | EMS | R99 |  | EMS |  |  |
| 5039 | 1170.5 | Mobile Station Execution Environment |  | 261d? | 1999-01-01 A | 1999-12-31 A | 100% | 1999-01-01 | 1999-12-31 | 261d? | start no earlier than 1999-01-01 | S1; SMG1; T2 | 6264h | 6264h | MExE | R99 | Alain | MExE |  |  |
| 5040 | 1170.6 | MS_Classmark |  | 261d? | 1999-01-01 A | 1999-12-31 A | 100% | 1999-01-01 | 1999-12-31 | 261d? | start no earlier than 1999-01-01 | N1 | 2088h | 2088h | MS_Classmark | R99 | Frederic | MS_Classmark |  |  |

Notes:
- 5015: -
- 5016: - / Impacted TSs and TRs: 26.226, 26.230
- 5017: - / Impacted TSs and TRs: 26.231
- 5018: RP#45 work item abandoned/closed (it was never really started)
- 5019: -
- 5020: -
- 5021: - / Impacted TSs and TRs: 22.101
- 5022: - / Impacted TSs and TRs: 22.100
- 5023: Requirement for high quality speech in UMTS Phase 1 but not in R99 / Impacted TSs and TRs: 22.105
- 5024: wid Architecture overview of the GSM-UMTS System, Architecture the GSM-UMTS Platform and New Access Network to Core Network (BSS-NSS) interface / Impacted TSs and TRs: 23.002, 23.008, 23.060, 23.101, 23.110
- 5025: - / Impacted TSs and TRs: 22.011, 22.038, 22.060, 22.078, 22.100, 22.101, 22.105, 22.115, 22.129, 23.002, 23.060, 24.007, 24.008, 25.101, 25.102, 25.104, 25.105, 25.113, 25.123, 25.133, 25.141, 25.142, 25.201, 25.211, 25.212, 25.213, 25.214, 25.215, 25.221, 25.222, 25.223, 25.224,
- 5026: - / Impacted TSs and TRs: 25.307 CR#0002, 0003 Inclusion of release independent RF related information
- 5027: Define the default speech codec for UMTS (both for FDD and TDD). Definition limited to selection of one codec among several existing ones/proposed codecs: GSM AMR, IS127 EVRC, ITU G.729 and MPEG-4 speech codec. / Impacted TSs and TRs: 04.08, 05.01, 05.02, 05.03, 05.05, 05.08, 05.09, 05.09, 05.50, 08.60, 08.61, 11.21, 26.071, 26.073, 26.074, 26.090, 26.091, 26.092, 26.093, 26.094, 26.101, 26.102, 26.103, 26.104, 26.975
- 5028: - / Impacted TSs and TRs: 26.104, 26.110, 26.111, 26.911, 26.912, 26.915
- 5029: - / Impacted TSs and TRs: 26.131, 26.132
- 5030: - / Impacted TSs and TRs: 24.022, 27.001, 29.007
- 5031: - / Impacted TSs and TRs: 27.060, 29.061
- 5032: -
- 5033: MMS allows users to send/receive messages e.g. almost unlimited text length, images, audio and video clips and new content types. R99 only includes the concept. MMS stage 3 is not included in 23.140. Rel-4 adds detailed architecture and protocols. / Impacted TSs and TRs: 22.140, 23.040, 23.140
- 5034: LCS provide ability to localize a terminal / Impacted TSs and TRs: 02.07, 03.71, 04.31, 04.35, 04.71, 05.05, 08.08, 08.31, 08.71, 09.31, 22.071, 23.002, 23.003, 23.007, 23.008, 23.016, 23.018, 23.032, 23.171, 24.007, 24.008, 24.030, 24.080, 25.305, 25.306, 25.331, 25.413, 25.423, 29.002, 29.010
- 5035: CAMEL is a network feature providing mechanisms to support services of operators which are not covered by standardised services, even when roaming outside the HPLMN. / Impacted TSs and TRs: 22.101, 23.008, 23.012, 23.016, 23.018, 23.060, 23.072, 23.078, 23.079, 23.082, 23.093, 29.002, 29.078
- 5036: - / Impacted TSs and TRs: 22.078, 23.078, 29.078
- 5037: MSP is an optional service enabling mobile subscribers to have several profiles associated with a single IMSI, with each profile being a subscription option. Each profile may be used for mobile originated and mobile terminated calls. / Impacted TSs and TRs: 22.097 (Advanced Addressing)
- 5038: SMS for 3G terminals compatible with GSM SMS. Added Enhanced Messaging Service (EMS) allowing small pictures, sounds, animations to be transferred via SMS. / Impacted TSs and TRs: 23.038, 23.039, 23.040, 23.042
- 5039: MExE provides a standardized MS execution environment and ability to negotiate its supported capabilities with a MExE SP. R99 enhances SIM MExE certificate management, security clarifications, QoS and defines two MExE classmarks WAP/Personal-Java based. / Impacted TSs and TRs: 02.57, 22.057, 22.101, 23.057
- 5040: MExE classmark identifies a category of MExE UE supporting MExE functionality with a minimum level of processing, memory, display, and interactive capabilities. Several MExE classmarks may be defined. / Impacted TSs and TRs: 24.008

| ID | WBS | Task | Duration | Start | Finish | Complete | Baseline start | Baseline finish | Baseline duration | Constraint | Resources | Work | Actual work | Acronym | Release | MCC resp | Acronym_3GU_Export | TSG stopped |
| --- | --- | --- | --- | --- | --- | --- | --- | --- | --- | --- | --- | --- | --- | --- | --- | --- | --- | --- |
| 5041 | 1170.7 | **MultiCall** | 261d? | 1999-01-01 A | 1999-12-31 A | 100% | 1999-01-01 | 1999-12-31 | 261d? |  | S1; N1; N2; N4 | 10440h | 10440h | Multicall | R99 | Alain | Multicall |  |
| 5042 | 1170.7.1 | Stage 1 for Multicall | 261d? | 1999-01-01 A | 1999-12-31 A | 100% | 1999-01-01 | 1999-12-31 | 261d? | start no earlier than 1999-01-01 | S1 | 2088h | 2088h |  | R99 | Alain |  |  |
| 5043 | 1170.8 | Virtual Home Environment | 261d? | 1999-01-01 A | 1999-12-31 A | 100% | 1999-01-01 | 1999-12-31 | 261d? | start no earlier than 1999-01-01 | S1; SMG1; S2 | 6264h | 6264h | VHE | R99 | Alain | VHE |  |
| 5044 | 1170.9 | Open Service Access | 261d? | 1999-01-01 A | 1999-12-31 A | 100% | 1999-01-01 | 1999-12-31 | 261d? | start no earlier than 1999-01-01 | S1; S2; N5 | 6264h | 6264h | OSA | R99 | Alain | OSA |  |
| 5045 | 1170.10 | Super Charger mechanism for signalling traffic associated with mobility | 261d? | 1999-01-01 A | 1999-12-31 A | 100% | 1999-01-01 | 1999-12-31 | 261d? | start no earlier than 1999-01-01 | N2; N4 | 4176h | 4176h | Super_Charger | R99 | Kimmo | Super_Charger |  |
| 5046 | 1170.11 | Follow_Me service | 261d? | 1999-01-01 A | 1999-12-31 A | 100% | 1999-01-01 | 1999-12-31 | 261d? | start no earlier than 1999-01-01 | S1; N2; N4 | 6264h | 6264h | Follow_Me | R99 | Alain | Follow_Me |  |
| 5047 | 1170.12 | Wide area network Synchronization and object exchange | 261d? | 1999-01-01 A | 1999-12-31 A | 100% | 1999-01-01 | 1999-12-31 | 261d? | start no earlier than 1999-01-01 | T2 | 2088h | 2088h | SYNC | R99 |  | SYNC |  |
| 5048 | 1170.13 | **R99 Terminal Interfaces** | 261d? | 1999-01-01 A | 1999-12-31 A | 100% | 1999-01-01 | 1999-12-31 | 261d? |  | T2 | 8352h | 8352h |  | R99 |  |  |  |
| 5049 | 1170.13.1 | AT commands for 3GPP | 261d? | 1999-01-01 A | 1999-12-31 A | 100% | 1999-01-01 | 1999-12-31 | 261d? | start no earlier than 1999-01-01 | T2 | 2088h | 2088h |  | R99 |  |  |  |
| 5050 | 1170.13.2 | Physical interfaces | 261d? | 1999-01-01 A | 1999-12-31 A | 100% | 1999-01-01 | 1999-12-31 | 261d? | start no earlier than 1999-01-01 | T2 | 2088h | 2088h |  | R99 |  |  |  |
| 5051 | 1170.13.3 | Multiplexer | 261d? | 1999-01-01 A | 1999-12-31 A | 100% | 1999-01-01 | 1999-12-31 | 261d? | start no earlier than 1999-01-01 | T2 | 2088h | 2088h | MUX MS-TE | R99 |  | MUX MS-TE |  |
| 5052 | 1170.14 | **Bearer Services** | 261d? | 1999-01-01 A | 1999-12-31 A | 100% | 1999-01-01 | 1999-12-31 | 261d? |  | S1; T2; N1; N3 | 41760h | 41760h |  | R99 | Alain |  |  |
| 5053 | 1170.14.1 | **Circuit Switched Bearer Services** | 261d? | 1999-01-01 A | 1999-12-31 A | 100% | 1999-01-01 | 1999-12-31 | 261d? |  | S1; N3 | 16704h | 16704h | Circuit_switched_Bearer_Services | R99 | Alain | Circuit_switched_Bearer_Services |  |
| 5054 | 1170.14.1.1 | Stage 1 for Circuit Switched Bearer Services | 261d? | 1999-01-01 A | 1999-12-31 A | 100% | 1999-01-01 | 1999-12-31 | 261d? | start no earlier than 1999-01-01 | S1 | 2088h | 2088h | CS_Bearerss_in_UMTS | R99 | Alain | CS_Bearerss_in_UMTS |  |
| 5055 | 1170.14.1.2 | CS_Bearers | 261d? | 1999-01-01 A | 1999-12-31 A | 100% | 1999-01-01 | 1999-12-31 | 261d? | start no earlier than 1999-01-01 | N3 | 2088h | 2088h | CS_Bearers | R99 | Gwiho | CS_Bearers |  |
| 5056 | 1170.14.1.3 | CS_Bearerss | 261d? | 1999-01-01 A | 1999-12-31 A | 100% | 1999-01-01 | 1999-12-31 | 261d? | start no earlier than 1999-01-01 | N3 | 2088h | 2088h | CS_Bearerss | R99 | Gwiho | CS_Bearerss |  |
| 5057 | 1170.14.1.4 | CS_Data | 261d? | 1999-01-01 A | 1999-12-31 A | 100% | 1999-01-01 | 1999-12-31 | 261d? | start no earlier than 1999-01-01 | N3 | 2088h | 2088h | CS_Data | R99 | Gwiho | CS_Data |  |
| 5058 | 1170.14.1.5 | CS_Data_Bearers | 261d? | 1999-01-01 A | 1999-12-31 A | 100% | 1999-01-01 | 1999-12-31 | 261d? | start no earlier than 1999-01-01 | N3 | 2088h | 2088h | CS_Data_Bearers | R99 | Gwiho | CS_Data_Bearers |  |
| 5059 | 1170.14.1.6 | Deleted - CN3 poart of Circuit Switched Bearer Services | 261d? | 1999-01-01 A | 1999-12-31 A | 100% | 1999-01-01 | 1999-12-31 | 261d? | start no earlier than 1999-01-01 | N3 | 2088h | 2088h | CSBS | R99 | Gwiho | CSBS | NP-06 |
| 5060 | 1170.14.2 | Frame Tunnelling Mode | 261d? | 1999-01-01 A | 1999-12-31 A | 100% | 1999-01-01 | 1999-12-31 | 261d? | start no earlier than 1999-01-01 | T2; N1; N3 | 6264h | 6264h | FTM | R99 | Gwiho | FTM |  |
| 5061 | 1170.14.3 | Access to ISPs and Intranets – Wireless/Remote access to LANs | 261d? | 1999-01-01 A | 1999-12-31 A | 100% | 1999-01-01 | 1999-12-31 | 261d? | start no earlier than 1999-01-01 | N3 | 2088h | 2088h | Interworking with PDN (DHCP) | R99 | Gwiho | Interworking with PDN (DHCP) |  |
| 5062 | 1170.14.4 | **PHS Internet Access Forum Specification** | 261d? | 1999-01-01 A | 1999-12-31 A | 100% | 1999-01-01 | 1999-12-31 | 261d? |  | S1; N3 | 8352h | 8352h | PIAFS | R99 | Alain | PIAFS |  |
| 5063 | 1170.14.4.1 | Personal Handyphone System Internet Access Forum Standard (PIAFS) | 261d? | 1999-01-01 A | 1999-12-31 A | 100% | 1999-01-01 | 1999-12-31 | 261d? | start no earlier than 1999-01-01 | S1 | 2088h | 2088h |  | R99 | Alain |  |  |
| 5064 | 1170.14.4.2 | Support_of_PIAFS_in_UMTS | 261d? | 1999-01-01 A | 1999-12-31 A | 100% | 1999-01-01 | 1999-12-31 | 261d? | start no earlier than 1999-01-01 | N3 | 2088h | 2088h | Support_of_PIAFS_in_UMTS | R99 | Gwiho | Support_of_PIAFS_in_UMTS |  |

Notes:
- 5041: Multicall allows several simultaneous CS calls with dedicated bearers of independent traffic and performance characteristics. R99 Multicall was defined as a supplementary service limited to one CS bearer to be used for speech at any time. / Impacted TSs and TRs: 22.030, 22.083, 22.087, 23.008, 23.009, 23.016, 23.018, 23.108, 23.135, 24.008, 24.080, 24.135, 29.002, 29.010
- 5042: - / Impacted TSs and TRs: 22.030, 22.083, 22.087
- 5043: Information exists in SP#5-8 reports & in SP-99416,SP-000095,SP 000155. OSA allows service development by operators and 3rd parties by making use of network functionality through open, standardised, secure, extensible and scalable interfaces. / Impacted TSs and TRs: 02.01, 22.105, 22.121,23.127
- 5044: Open Service Architecture became in later Releases Open Service Access. Produced by Parlay, ETSI SPAN (TISPAN), 3GPP SA1 (Stage 1), SA2 (Stage 2) and CN5 (Stage 3), resulting in a single set of standard OSA APIs for the whole development community. / Impacted TSs and TRs: 22.121, 23.127, 29.198, 29.998
- 5045: Super Charger reduces mobility management cost by reducing the volume of location update signalling. It changes subscriber data management associated with inter-VLR and SGSN location updates. It also applies to packet services (SGSN replaces VLR and … / Impacted TSs and TRs: 21.905, 23.007, 23.008, 23.012, 23.016, 23.018, 23.040, 23.060, 23.116, 23.912, 29.002
- 5046: Follow Me enables a mobile subscriber A to manipulate the Follow Me data of a party B in such a way that - under certain conditions - subsequent calls directed to party B will be forwarded to subscriber A. It is PLMN-specific and control based on USSD / Impacted TSs and TRs: 21.905, 22.004, 22.030, 22.082, 22.090, 22.094, 23.090, 24.090, 22.094, 23.011, 23.015, 23.082, 29.002
- 5047: Allows data stored in ME/USIM to be synchronized with the outside world. TS 27.103 defines protocols based upon IrMC level 4 and will evaluate new technologies (XML) for inclusion. From Rel-4 IrMC was replaced by SyncML in 27.103. / Impacted TSs and TRs: 27.103, 27.903
- 5048: -
- 5049: AT commands to control a 3G ME via an external Terminal Equipment (TE), fully compatible with GSM AT commands. R99 adds new AT commands e.g. to control Advanced Speech Call Items (ASCI) services. / Impacted TSs and TRs: 27.005, 27.007
- 5050: Conclusion: 3GPP should not produce any technical specification for terminal interfaces other than radio interface and USIM interface. SDOs could develop own optional physical connector specification based on market requirements / Impacted TSs and TRs: 27.901
- 5051: Multiplexing protocol allowing a number of simultaneous sessions between a MS and a terminal; used to send any data (voice, SMS, USSD, fax etc.). 27.010 describes the protocol, but not the commands or data transported with it. / Impacted TSs and TRs: 27.010
- 5052: -
- 5053: CS and real-time data services provided for interworking with PSTN/ISDN so that user is unaware of access network used (UMTS, GSM or handover between ANs). Transparent(constant delay) & non-transparent(zero error with flow control) services are supported / Impacted TSs and TRs: 22.002, 23.910, 27.001, 29.007
- 5054: CS and real-time data services provided for interworking with PSTN/ISDN so that user is unaware of access network used (UMTS, GSM or handover between ANs). Transparent(constant delay) & non-transparent(zero error with flow control) services are supported / Impacted TSs and TRs: 22.002
- 5055: - / Impacted TSs and TRs: 29.007
- 5056: - / Impacted TSs and TRs: 04.21, 23.910, 27.001, 29.007
- 5057: - / Impacted TSs and TRs: 27.001, 27.002, 27.003, 29.007
- 5058: - / Impacted TSs and TRs: 23.910, 27.001, 29.007
- 5059: No CR or new TS/TR approved under this WI / Impacted TSs and TRs: 23.910, 27.001, 29.007
- 5060: FTM is a type of async non-transparent CS bearer service (22.002). Generic term for HDLC and HDLC-related transmission protocols. Converts async non-transp data stream towards mobile side & sync data stream using X.31 flag stuffing on fixed network side. / Impacted TSs and TRs: 22.002, 27.001, 27.007, 29.007
- 5061: Access to an Intranet or ISP by running DHCP between the TE and a server in the Intranet/ISP domain. / Impacted TSs and TRs: 29.061
- 5062: PIAFS is one type of CS bearer data service (22.002). It refers to async CS tx protocol over ISDN 64 kbit/s unrestricted digital line. Facilitates interworking between PHS-MS and UMTS-UE & UMTS-UE and existing PIAFS TA (Terminal Adapter). / Impacted TSs and TRs: 22.002, 27.001, 27.007, 29.007
- 5063: PIAFS was originally standardised by the PHS Internet Access Forum in Japan. More information can be found at: http://www.infopro.or.jp/piaf / Impacted TSs and TRs: 22.002
- 5064: - / Impacted TSs and TRs: 27.001, 27.007, 29.007

| ID | WBS | Task | Duration | Start | Finish | Complete | Baseline start | Baseline finish | Baseline duration | Constraint | Resources | Work | Actual work | Acronym | Release | MCC resp | Acronym_3GU_Export | TSG stopped |
| --- | --- | --- | --- | --- | --- | --- | --- | --- | --- | --- | --- | --- | --- | --- | --- | --- | --- | --- |
| 5065 | 1170.15 | **Universal Integrated Circuit Card (UICC) and Universal Subscriber Identity Module (USIM)** | 261d? | 1999-01-01 A | 1999-12-31 A | 100% | 1999-01-01 | 1999-12-31 | 261d? |  | T3 | 31320h | 31320h | UICC, USIM | R99 | Xavier | UICC, USIM |  |
| 5066 | 1170.15.1 | UICC / Terminal interface; Physical and logical characteristics | 261d? | 1999-01-01 A | 1999-12-31 A | 100% | 1999-01-01 | 1999-12-31 | 261d? | start no earlier than 1999-01-01 | T3 | 2088h | 2088h | UICC | R99 | Xavier | UICC |  |
| 5067 | 1170.15.2 | UICC/(U)SIM enhancements and interworking | 261d? | 1999-01-01 A | 1999-12-31 A | 100% | 1999-01-01 | 1999-12-31 | 261d? | start no earlier than 1999-01-01 | T3 | 2088h | 2088h | UICC99 | R99 | Xavier | UICC1 |  |
| 5068 | 1170.15.3 | Characteristics of the USIM application | 261d? | 1999-01-01 A | 1999-12-31 A | 100% | 1999-01-01 | 1999-12-31 | 261d? | start no earlier than 1999-01-01 | T3 | 2088h | 2088h | USIM | R99 | Xavier | USIM |  |
| 5069 | 1170.15.4 | UICC Application Identifiers | 261d? | 1999-01-01 A | 1999-12-31 A | 100% | 1999-01-01 | 1999-12-31 | 261d? | start no earlier than 1999-01-01 | T3 | 2088h | 2088h | AID, Application_Identifiers | R99 | Xavier | AID, Application_Identifiers |  |
| 5070 | 1170.15.5 | SIM Application Toolkit | 261d? | 1999-01-01 A | 1999-12-31 A | 100% | 1999-01-01 | 1999-12-31 | 261d? | start no earlier than 1999-01-01 | S1; T3 | 4176h | 4176h | SAT | R99 | Alain | SAT |  |
| 5071 | 1170.15.6 | USIM Application Toolkit | 261d? | 1999-01-01 A | 1999-12-31 A | 100% | 1999-01-01 | 1999-12-31 | 261d? | start no earlier than 1999-01-01 | T3 | 2088h | 2088h | USAT | R99 | Xavier | USAT |  |
| 5072 | 1170.15.7 | Bearer Independent Protocol for SAT applications to exchange data over the GSM network | 261d? | 1999-01-01 A | 1999-12-31 A | 100% | 1999-01-01 | 1999-12-31 | 261d? | start no earlier than 1999-01-01 | T3 | 2088h | 2088h | BIP | R99 | Xavier | BIP |  |
| 5073 | 1170.15.8 | Administrative commands and functions for IC cards | 261d? | 1999-01-01 A | 1999-12-31 A | 100% | 1999-01-01 | 1999-12-31 | 261d? | start no earlier than 1999-01-01 | T3 | 2088h | 2088h |  | R99 | Xavier |  |  |
| 5074 | 1170.15.9 | USIM and UICC requirements | 261d? | 1999-01-01 A | 1999-12-31 A | 100% | 1999-01-01 | 1999-12-31 | 261d? | start no earlier than 1999-01-01 | T3 | 2088h | 2088h |  | R99 | Xavier |  |  |
| 5075 | 1170.15.10 | SIM_API | 261d? | 1999-01-01 A | 1999-12-31 A | 100% | 1999-01-01 | 1999-12-31 | 261d? | start no earlier than 1999-01-01 | T3 | 2088h | 2088h | SIM_API | R99 | Xavier | SIM_API |  |
| 5076 | 1170.15.11 | SIM_toolkit_API | 261d? | 1999-01-01 A | 1999-12-31 A | 100% | 1999-01-01 | 1999-12-31 | 261d? | start no earlier than 1999-01-01 | SMG9; T3 | 4176h | 4176h | SIM_toolkit | R99 | Xavier | SIM_toolkit |  |
| 5077 | 1170.15.12 | Deleted - 1.8 Volt SIM ME interface | 261d? | 1999-01-01 A | 1999-12-31 A | 100% | 1999-01-01 | 1999-12-31 | 261d? | start no earlier than 1999-01-01 | SMG9 | 2088h | 2088h | SMIME_1.8V | R99 | Xavier | SMIME_1.8V | TP-06 |
| 5078 | 1170.16 | **USIM/UICC Testing** | 261d? | 1999-01-01 A | 1999-12-31 A | 100% | 1999-01-01 | 1999-12-31 | 261d? |  | T3 | 10440h | 10440h |  | R99 | Xavier |  |  |
| 5079 | 1170.16.1 | Terminal tests for the UICC Interface | 261d? | 1999-01-01 A | 1999-12-31 A | 100% | 1999-01-01 | 1999-12-31 | 261d? | start no earlier than 1999-01-01 | T3 | 2088h | 2088h |  | R99 | Xavier |  |  |
| 5080 | 1170.16.2 | USIM application test specification | 261d? | 1999-01-01 A | 1999-12-31 A | 100% | 1999-01-01 | 1999-12-31 | 261d? | start no earlier than 1999-01-01 | T3 | 2088h | 2088h |  | R99 | Xavier |  |  |
| 5081 | 1170.16.3 | USIM conformance test specification | 261d? | 1999-01-01 A | 1999-12-31 A | 100% | 1999-01-01 | 1999-12-31 | 261d? | start no earlier than 1999-01-01 | T3 | 2088h | 2088h |  | R99 | Xavier |  |  |
| 5082 | 1170.16.4 | SIM toolkit test specification | 261d? | 1999-01-01 A | 1999-12-31 A | 100% | 1999-01-01 | 1999-12-31 | 261d? | start no earlier than 1999-01-01 | T3 | 2088h | 2088h |  | R99 | Xavier |  |  |
| 5083 | 1170.17 | **Security for UMTS and GSM Features** | 261d? | 1999-01-01 A | 1999-12-31 A | 100% | 1999-01-01 | 1999-12-31 | 261d? |  | S3; N2; N4 | 16704h | 16704h | Security | R99 | Mirko | Security |  |
| 5084 | 1170.17.1 | Fraud Information Gathering Service (for connection-orientated services) | 261d? | 1999-01-01 A | 1999-12-31 A | 100% | 1999-01-01 | 1999-12-31 | 261d? | start no earlier than 1999-01-01 | S3 | 2088h | 2088h | FIGS | R99 | Mirko | FIGS |  |
| 5085 | 1170.17.2 | Immediate Service Termination / SECurity Immediate Service Termination | 261d? | 1999-01-01 A | 1999-12-31 A | 100% | 1999-01-01 | 1999-12-31 | 261d? | start no earlier than 1999-01-01 | S3; N2; N4 | 6264h | 6264h | IST, SECIST | R99 | Mirko | IST, SECIST |  |
| 5086 | 1170.17.3 | Core_Network_Security | 261d? | 1999-01-01 A | 1999-12-31 A | 100% | 1999-01-01 | 1999-12-31 | 261d? | start no earlier than 1999-01-01 | N4 | 2088h | 2088h | Core_Network_Security | R99 | Kimmo | Core_Network_Security |  |
| 5087 | 1171 | **GSM Features** | 261d? | 1999-01-01 A | 1999-12-31 A | 100% | 1999-01-01 | 1999-12-31 | 261d? |  | S1; S2; SMG; T2; N1; N2; N3; N4 | 164952h | 164952h |  | R99 | Alain |  |  |
| 5088 | 1171.1 | **Dual Transfer Mode within GSM and GPRS** | 261d? | 1999-01-01 A | 1999-12-31 A | 100% | 1999-01-01 | 1999-12-31 | 261d? |  | SMG; N1 | 10440h | 10440h | DTM | R99 | Frederic | DTM |  |
| 5089 | 1171.1.1 | Class A Dual Transfer Mode | 261d? | 1999-01-01 A | 1999-12-31 A | 100% | 1999-01-01 | 1999-12-31 | 261d? | start no earlier than 1999-01-01 | SMG | 2088h | 2088h | Class_A_Dual_Transfer_Mode_(DTM) | R99 | Frederic | Class_A_Dual_Transfer_Mode_(DTM) |  |
| 5090 | 1171.1.2 | Dual Transfer Mode | 261d? | 1999-01-01 A | 1999-12-31 A | 100% | 1999-01-01 | 1999-12-31 | 261d? | start no earlier than 1999-01-01 | SMG; N1 | 4176h | 4176h |  | R99 | Frederic |  |  |

Notes:
- 5065: For 3G, GSM 11.11 was divided into two parts: a platform comprised of basic physical, electrical and logical specification (31.101) and an application specification (31.102)
- 5066: Defines a generic Terminal/Integrated Circuit Card (ICC) interface. Is independent of 3G USIM application => platform for any IC card application. Ensures interoperability between ICC and terminal independently of manufacturer, card issuer or operator. / Impacted TSs and TRs: 31.101 (Since 10/2000, ETSI EP SCP is responsible for the generic Terminal/Integrated Circuit Card (ICC) interface TS 102 221)
- 5067: Acronym changed from UICC1 / Impacted TSs and TRs: 31.102, 31.900
- 5068: Defines Universal Subscriber Identity Module (USIM) application for 3G telecom network operation & resides on UICC, an IC card specified in 31.101. UICC can be used as a multi-application card: several USIMs and/or other applications can co-exist / Impacted TSs and TRs: 31.102
- 5069: Defines and administers Application IDentifiers (AID) for UICC. AID is used to address an application in the card. Consists of Registered application provider ID (RID) & Proprietary application ID exception (PIX - according to ISO/IEC 7816-5). / Impacted TSs and TRs: 21.111, 31.110
- 5070: - / Impacted TSs and TRs: 11.14, 22.030, 22.100, 22.101
- 5071: Defines UICC - ME interface, and mandatory ME procedures for USAT. Based on GSM 11.14 (SIM Application Toolkit). Commands and procedures defined in USIM and 3G Terminal for using USAT. Service and security requirements defined in 22.100 and 22.101. / Impacted TSs and TRs: 31.111
- 5072: Defines at SIM-ME interface a basic protocol allowing SIM Toolkit applications to determine available bearers and to exchange data by selecting using the most appropriate bearer available (CS data, GPRS, SMS, Unstructured Supplementary Service Data (USSD) / Impacted TSs and TRs: 03.48, 11.10, 11.14
- 5073: Defines function and syntax of administrative commands for telecommunication IC Card used during installation, activation and de-activation of applications. Compliant to ISO/IEC 7816 series. Handed over to ETSI Project Smart Card Platform (SCP) in 2000. / Impacted TSs and TRs: ETSI TS 102 222
- 5074: High level requirements for 3GPP IC card and its interface to 3GPP terminal (USIM&UICC reqs). Service&security reqs in 322.01,22.00. USIM is a 3GPP application on an IC card. Inter-operates with 3GPP terminals and provides access to 3GPP services / Impacted TSs and TRs: 21.111
- 5075: - / Impacted TSs and TRs: 03.19
- 5076: - / Impacted TSs and TRs: 03.48, 11.11, 11.14
- 5077: No CR or new TS/TR approved under this WI / Impacted TSs and TRs: 11.18
- 5078: -
- 5079: Test spec for the interface between UICC and terminal (originally based GSM 11.10-1 clause 27). Ensures UICC - terminal interoperability independently of manufacturer, card issuer or operator. Tests for applications residing on UICC are in 31.121 / Impacted TSs and TRs: 31.120
- 5080: Application test spec originally based on GSM 11.17. Aspects related to UICC administrative management phase are not defined. Any internal technical realisation of either UICC or terminal is only specified where these are reflected over the interface. / Impacted TSs and TRs: 31.121
- 5081: Conformance Test specification for UICC defined in 31.101 with USIM defined in 31.102. / Impacted TSs and TRs: 31.122
- 5082: SIM Application Toolkit (SAT) has major impact on ME design and enhances SIM/ME interface. Contains tests for SIM/ME interface optional features (no network related signalling issues involved). Doesn't form basis for any type approval or regulatory tests. / Impacted TSs and TRs: 11.10-4
- 5083: - / Impacted TSs and TRs: 02.09, 03.20, 21.133, 22.022, 23.003, 23.007, 23.008, 23.012, 23.018, 24.007, 24.008, 24.010, 24.011, 29.002, 29.060, New (33.102, 33.103, 33.105, 33.107, 35.201)
- 5084: HPLMN can monitor its subscribers in VPLMN, which collects info on a defined set of monitored subscribers activities & sends it to HPLMN, which can perform service limitation control eg Operator Determined Barring (ODB) and IST to limit financial exposure / Impacted TSs and TRs: New 22.031, 23.031
- 5085: HPLMN can terminate all activities of its subscriber in VPLMN, if decides (based on info via eg FIGS) that a roaming subscriber is behaving in fraudulent/suspicious way. HPLMN can terminate all subscriber activities including calls in progress. / Impacted TSs and TRs: 03.35, 22.032, 23.008, 23.016, 23.035, 29.002
- 5086: - / Impacted TSs and TRs: 29.002
- 5087: -
- 5088: 2-99-1780 (2-99-H80 from SMG2#32) WID on BSS co-ordination of Radio Resource allocation for class A GPRS services - GSM Radio Access (R99) / Impacted TSs and TRs: 03.55, 03.64, 04.18, 04.60, 05.01, 05.02, 05.08, 08.08, 23.060, 24.007, 24.008
- 5089: - / Impacted TSs and TRs: 05.10
- 5090: - / Impacted TSs and TRs: 03.55, 03.64, 04.18, 05.01, 05.02, 05.08, 24.008

| ID | WBS | Task | Duration | Start | Finish | Complete | Baseline start | Baseline finish | Baseline duration | Constraint | Resources | Work | Actual work | Acronym | Release | MCC resp | Acronym_3GU_Export | TSG stopped | WI rapporteur name | WI rapporteur e-mail |
| --- | --- | --- | --- | --- | --- | --- | --- | --- | --- | --- | --- | --- | --- | --- | --- | --- | --- | --- | --- | --- |
| 5091 | 1171.2 | **General Packet Radio Service enahancements** | 261d? | 1999-01-01 A | 1999-12-31 A | 100% | 1999-01-01 | 1999-12-31 | 261d? |  | S1; S2; SMG1; SMG2; SMG7; N1; N2; N3; N4; T2 | 50112h | 50112h | GPRS enhancements | R99 | Alain | GPRS enhancements |  |  |  |
| 5092 | 1171.2.1 | General Packet Radio Service | 261d? | 1999-01-01 A | 1999-12-31 A | 100% | 1999-01-01 | 1999-12-31 | 261d? | start no earlier than 1999-01-01 | S1; S2; SMG1; SMG2; SMG7; N1; N2; N3; N4; T2 | 20880h | 20880h | GPRS | R99 | Alain | GPRS |  |  |  |
| 5093 | 1171.2.2 | GPRS2 | 261d? | 1999-01-01 A | 1999-12-31 A | 100% | 1999-01-01 | 1999-12-31 | 261d? | start no earlier than 1999-01-01 | SMG1; N2 | 4176h | 4176h | GPRS2 | R99 |  | GPRS2 |  |  |  |
| 5094 | 1171.2.3 | GPRS Tunnelling Protocol enhancement | 261d? | 1999-01-01 A | 1999-12-31 A | 100% | 1999-01-01 | 1999-12-31 | 261d? | start no earlier than 1999-01-01 | N4; N2 | 4176h | 4176h | GTP_enhancement | R99 | Kimmo | GTP_enhancement |  |  |  |
| 5095 | 1171.3 | **Enhanced Data rates for GSM Evolution - Phase 1** | 261d? | 1999-01-01 A | 1999-12-31 A | 100% | 1999-01-01 | 1999-12-31 | 261d? |  | SMG2; SMG1; SMG3; SMG4; SMG7; SMG9; SMG10; N1; N3; T2 | 73080h | 73080h | EDGE - Phase 1 | R99 | Maurice | EDGE - Phase 1 |  |  |  |
| 5096 | 1171.3.1 | Enhanced Data rates for GSM Evolution | 261d? | 1999-01-01 A | 1999-12-31 A | 100% | 1999-01-01 | 1999-12-31 | 261d? | start no earlier than 1999-01-01 | SMG2; SMG1; SMG3; SMG4; SMG7; SMG9; SMG10; N1; N3; T2 | 20880h | 20880h | EDGE | R99 | Maurice | EDGE |  |  |  |
| 5097 | 1171.3.2 | EDGE-Layer1 | 261d? | 1999-01-01 A | 1999-12-31 A | 100% | 1999-01-01 | 1999-12-31 | 261d? | start no earlier than 1999-01-01 | SMG2 | 2088h | 2088h | EDGE-Layer1 | R99 |  | EDGE-Layer1 |  |  |  |
| 5098 | 1171.3.3 | High Speed Circuit Switched Data | 261d? | 1999-01-01 A | 1999-12-31 A | 100% | 1999-01-01 | 1999-12-31 | 261d? | start no earlier than 1999-01-01 | SMG1; SMG2; SMG7 | 6264h | 6264h | HSCSD | R99 |  | HSCSD |  |  |  |
| 5099 | 1171.3.4 | Enhanced Circuit Switched Data - Phase 1 | 261d? | 1999-01-01 A | 1999-12-31 A | 100% | 1999-01-01 | 1999-12-31 | 261d? | start no earlier than 1999-01-01 | S1; SMG | 4176h | 4176h | ECSD | R99 | Alain | ECSD |  |  |  |
| 5100 | 1171.3.5 | EDGE-Enhanced Circuit Switched Data | 261d? | 1999-01-01 A | 1999-12-31 A | 100% | 1999-01-01 | 1999-12-31 | 261d? | start no earlier than 1999-01-01 | SMG2 | 2088h | 2088h | EDGE-ECSD | R99 |  | EDGE-ECSD |  |  |  |
| 5101 | 1171.3.6 | Enhanced GPRS - Phase 1 | 261d? | 1999-01-01 A | 1999-12-31 A | 100% | 1999-01-01 | 1999-12-31 | 261d? | start no earlier than 1999-01-01 | SMG; N1 | 4176h | 4176h | EGPRS | R99 |  | EGPRS |  |  |  |
| 5102 | 1171.3.7 | EDGE-EGPRS | 261d? | 1999-01-01 A | 1999-12-31 A | 100% | 1999-01-01 | 1999-12-31 | 261d? | start no earlier than 1999-01-01 | SMG2 | 2088h | 2088h | EDGE-EGPRS | R99 |  | EDGE-EGPRS |  |  |  |
| 5103 | 1171.3.8 | Packet Flow Context (PFC) | 261d? | 1999-01-01 A | 1999-12-31 A | 100% | 1999-01-01 | 1999-12-31 | 261d? | start no earlier than 1999-01-01 | SMG2 | 2088h | 2088h | PFC | R99 |  | PFC |  |  |  |
| 5104 | 1171.3.9 | Support for EGPRS in ANSI-136 networks and EDGE COMPACT | 261d? | 1999-01-01 A | 1999-12-31 A | 100% | 1999-01-01 | 1999-12-31 | 261d? | start no earlier than 1999-01-01 | SMG | 2088h | 2088h | EDGE-Compact | R99 |  | EDGE-Compact |  |  |  |
| 5105 | 1171.3.10 | EGPRS COMPACT | 261d? | 1999-01-01 A | 1999-12-31 A | 100% | 1999-01-01 | 1999-12-31 | 261d? | start no earlier than 1999-01-01 | SMG | 2088h | 2088h | EGPRS-Compact | R99 |  | EGPRS-Compact |  |  |  |
| 5106 | 1171.3.11 | COMPACT | 261d? | 1999-01-01 A | 1999-12-31 A | 100% | 1999-01-01 | 1999-12-31 | 261d? | start no earlier than 1999-01-01 | SMG; N1 | 4176h | 4176h | COMPACT | R99 |  | COMPACT |  |  |  |
| 5107 | 1171.4 | GSM_400 | 261d? | 1999-01-01 A | 1999-12-31 A | 100% | 1999-01-01 | 1999-12-31 | 261d? | start no earlier than 1999-01-01 | SMG2; SMG7; T2 | 6264h | 6264h | GSM_400 | R99 | Paolo | GSM_400 |  |  |  |
| 5108 | 1171.5 | GSM_450 | 261d? | 1999-01-01 A | 1999-12-31 A | 100% | 1999-01-01 | 1999-12-31 | 261d? | start no earlier than 1999-01-01 | SMG2 | 2088h | 2088h | GSM_450 | R99 |  | GSM_450 |  |  |  |
| 5109 | 1171.6 | GSM_700 | 261d? | 1999-01-01 A | 1999-12-31 A | 100% | 1999-01-01 | 1999-12-31 | 261d? | start no earlier than 1999-01-01 | SMG2 | 2088h | 2088h | GSM_700 | R99 |  | GSM_700 |  |  |  |
| 5110 | 1171.7 | Deleted - GERAN | 261d? | 1999-01-01 A | 1999-12-31 A | 100% | 1999-01-01 | 1999-12-31 | 261d? | start no earlier than 1999-01-01 | SMG2; S2 | 4176h | 4176h | GERAN | R99 | Maurice | GERAN | SP-06 |  |  |
| 5111 | 1172 | **GSM Features transposed to UMTS** | 261d? | 1999-01-01 A | 1999-12-31 A | 100% | 1999-01-01 | 1999-12-31 | 261d? |  | S1; S3; T2; N2; N4 | 31320h | 31320h |  | R99 | Alain |  |  |  |  |
| 5112 | 1172.1 | Cell Broadcast Service | 261d? | 1999-01-01 A | 1999-12-31 A | 100% | 1999-01-01 | 1999-12-31 | 261d? | start no earlier than 1999-01-01 | T2 | 2088h | 2088h | CBS | R99 |  | CBS |  |  |  |
| 5113 | 1172.2 | **GSM mobile number portability euro MNP / North American MNP** | 261d? | 1999-01-01 A | 1999-12-31 A | 100% | 1999-01-01 | 1999-12-31 | 261d? |  | S1; N2; N4 | 10440h | 10440h | MNP | R99 | Alain | MNP |  |  |  |
| 5114 | 1172.2.1 | Mobile Number Portability | 261d? | 1999-01-01 A | 1999-12-31 A | 100% | 1999-01-01 | 1999-12-31 | 261d? | start no earlier than 1999-01-01 | N2; N4 | 4176h | 4176h |  | R99 | Kimmo |  |  |  |  |
| 5115 | 1172.3 | Automatic establishment of roaming relations | 261d? | 1999-01-01 A | 1999-12-31 A | 100% | 1999-01-01 | 1999-12-31 | 261d? | start no earlier than 1999-01-01 | S1 | 2088h | 2088h |  | R99 | Alain |  |  | Telecom Italia | enrico.scarrone@telecomitalia.it |
| 5116 | 1172.4 | Advanced addressing | 261d? | 1999-01-01 A | 1999-12-31 A | 100% | 1999-01-01 | 1999-12-31 | 261d? | start no earlier than 1999-01-01 | S1 | 2088h | 2088h |  | R99 | Alain |  |  |  |  |
| 5117 | 1172.5 | UMTS numbering, addressing and identities | 261d? | 1999-01-01 A | 1999-12-31 A | 100% | 1999-01-01 | 1999-12-31 | 261d? | start no earlier than 1999-01-01 | S1 | 2088h | 2088h |  | R99 | Alain |  |  |  |  |
| 5118 | 1172.6 | Lawful Interception for GSM Features transposed to UMTS | 261d? | 1999-01-01 A | 1999-12-31 A | 100% | 1999-01-01 | 1999-12-31 | 261d? | start no earlier than 1999-01-01 | S3 | 2088h | 2088h | LI | R99 | Mirko | LI |  |  |  |

Notes:
- 5091: GPRS was introduced in Release 97. Release 99 brings a number of essential corrections e.g. on Downlink Power Control, Timing Advance procedure, Cell reselection delay time, PBCCH scheduling, PTCCH mapping, etc. / Impacted TSs and TRs: 05.02, 05.05, 05.08, 05.10, 05.50, 11.21, 23.064, 24.008, 24.060
- 5092: - / Impacted TSs and TRs: 02.60, 03.22, 03.64, 04.18, 04.60, 04.64, 04.65, 05.01, 05.02, 05.05, 05.08, 05.10, 08.08, 08.18, 11.10-1, 11.21, 22.041, 22.060, 23.003, 23.007, 23.060, 23.107, 23.122, 24.007, 24.008, 27.007, 27.060, 29.002, 29.016, 29.018, 29.060, 29.061
- 5093: Introduction of EGPRS (S1) + Introduction of Reserved Service Labels in the APN (N2) / Impacted TSs and TRs: 02.60, 23.003
- 5094: - / Impacted TSs and TRs: 23.003, 23.008, 29.060
- 5095: EDGE is independent of the frequency bands, so it can be deployed e.g. in 900 and 1900 MHz bands. The new physical layer based on 8-PSK modulation is introduced and EGPRS and ECSD facilitate the new modulation in single and multi slot constellation. / Impacted TSs and TRs: 10.59, 02.34, 02.60, 03.30, 05.10, 05.50, 11.26
- 5096: WID in SMG2 331/97, SMG 1147/97, SMG 1148/97 / Impacted TSs and TRs: 02.34, 03.10, 03.20, 03.64, 04.03, 04.04, 04.06, 04.08, 04.18, 04.21, 04.22, 04.60, 04.64, 05.01, 05.02, 05.03, 05.04, 05.05, 05.08, 05.10, 05.50, 07.01, 07.02, 07.03, 08.08, 08.20, 08.58, 08.60, 09.07, 09.18, 11.10-1, 11.11, 11.21, 11.26, 23.034, 24.008,
- 5097: WID in SMG2 331/97, SMG 1147/97, SMG 1148/97 / Impacted TSs and TRs: 05.05, 05.10, 05.50
- 5098: No additional features for R99. / Impacted TSs and TRs: 02.34, 04.18, 11.10-1
- 5099: ECSD supports both transparent and non-transparent services, up to 64 kbit/s and 57.6 kbit/s respectively. See Tdoc SMG2 670/99 ECSD Concept Evaluation for more info / Impacted TSs and TRs: 05.02, 08.58, 22.034
- 5100: - / Impacted TSs and TRs: 05.03
- 5101: - / Impacted TSs and TRs: 02.07, 03.64, 04.14, 04.18, 04.60, 05.05, 05.08, 24.008
- 5102: - / Impacted TSs and TRs: 05.03, 05.05, 05.08
- 5103: - / Impacted TSs and TRs: 04.18
- 5104: Support for EGPRS in ANSI-136 networks and EDGE Compact (for ANSI-136 networks only). COMPACT = Deployment of servicES in CP-150spectrum below 1 MHz / Impacted TSs and TRs: 03.22, 03.30, 03.64, 05.01, 05.02, 05.03, 05.05, 05.08, 05.10
- 5105: COMPACT = Deployment of servicES in CP-150spectrum below 1 MHz / Impacted TSs and TRs: 04.18, 05.02
- 5106: COMPACT = Deployment of servicES in CP-150spectrum below 1 MHz / Impacted TSs and TRs: 03.22, 04.18, 04.60, 05.08, 23.122, 24.008
- 5107: GSM in the 400 MHz bands allows to deploy GSM within frequency bands in the range 450 to 500 MHz, previously used for analogue cellular systems. See Tdoc SMG2 190/99 and 595/99 for further info. / Impacted TSs and TRs: 02.17, 03.22, 03.30, 04.04, 04.18, 04.60, 05.01, 05.02, 05.05, 05.08, 05.10, 05.50, 08.18, 08.58, 11.21, 24.008, 27.007
- 5108: - / Impacted TSs and TRs: 03.22, 03.30, 05.01, 05.05, 05.08
- 5109: - / Impacted TSs and TRs: 05.05
- 5110: No CR or new TS/TR approved under this WI / Impacted TSs and TRs: G2: 04.18 CR#A248 , 04.60 CR#B090
- 5111: -
- 5112: Moved to CT1 at TSG-T closure. Applicability of the Cell Broadcast Service (as defined for GSM network) to 3G networks / Impacted TSs and TRs: 23.041
- 5113: R98 MNP: mobile subscriber ability to change PLMN operator within the same country whilst retaining its original MS ISDN number (MSISDN). IMSI is changed, only MSISDN is kept. R99 adds requirements for North American Service Provider Number Portability. / Impacted TSs and TRs: 22.066
- 5114: - / Impacted TSs and TRs: 23.018, 23.066, 29.002
- 5115: framework for commercial and technical interworking between UMTS Home Environments and Serving Networks who have no direct prior commercial agreements with each other. / Impacted TSs and TRs: 22.101, 22.971
- 5116: - / Impacted TSs and TRs: 22.101, 22.75U, 22.975
- 5117: Also new requirements for Single and Multiple Numbering scheme was added (CR#20 and 21). Deleted the term International Mobile User Identifier (IMUI) and changed IMSI (International Mobile Station Identifier=>International Mobile Subscriber Identity. / Impacted TSs and TRs: 22.101
- 5118: Defines an interception system in UMTS that supports a number of regional interception regulations. Regional interception requirements shall be met in using specific (regional) mediation functions allowing only required information to be transported. / Impacted TSs and TRs: New 33.106, 33.107

| ID | WBS | Task | Duration | Start | Finish | Complete | Baseline start | Baseline finish | Baseline duration | Constraint | Resources | Work | Actual work | Release | MCC resp | Acronym | Acronym_3GU_Export | TSG stopped |
| --- | --- | --- | --- | --- | --- | --- | --- | --- | --- | --- | --- | --- | --- | --- | --- | --- | --- | --- |
| 5119 | 1173 | **Charging** | 261d? | 1999-01-01 A | 1999-12-31 A | 100% | 1999-01-01 | 1999-12-31 | 261d? |  | S1; S5 | 8352h | 8352h | R99 | Alain |  |  |  |
| 5120 | 1173.1 | R99 Charging | 261d? | 1999-01-01 A | 1999-12-31 A | 100% | 1999-01-01 | 1999-12-31 | 261d? | start no earlier than 1999-01-01 | S1 | 2088h | 2088h | R99 | Alain | Charging | Charging |  |
| 5121 | 1173.2 | R99 OAM Charging Management | 261d? | 1999-01-01 A | 1999-12-31 A | 100% | 1999-01-01 | 1999-12-31 | 261d? | start no earlier than 1999-01-01 | S5 | 2088h | 2088h | R99 | Mirko | OAMCH, CH | OAMCH, CH |  |
| 5122 | 1174 | **Operations, Administration, Maintenance and Provisioning (OAM&P)** | 261d? | 1999-01-01 A | 1999-12-31 A | 100% | 1999-01-01 | 1999-12-31 | 261d? |  | S5 | 12528h | 12528h | R99 | Mirko | OAM1999 | OAM1999 |  |
| 5123 | 1174.1 | OAM Principles and High-level Requirements | 261d? | 1999-01-01 A | 1999-12-31 A | 100% | 1999-01-01 | 1999-12-31 | 261d? | start no earlier than 1999-01-01 | S5 | 2088h | 2088h | R99 | Mirko | PR, Princs_&_Reqs_(PR) | PR, Princs_&_Reqs_(PR) |  |
| 5124 | 1174.2 | OAM Architecture | 261d? | 1999-01-01 A | 1999-12-31 A | 100% | 1999-01-01 | 1999-12-31 | 261d? | start no earlier than 1999-01-01 | S5 | 2088h | 2088h | R99 | Mirko | OAMAR, AR, Telecom_Management_Arch_(AR) | OAMAR, AR, Telecom_Management_Arch_(AR) |  |
| 5125 | 1174.3 | OAM Configuration Management | 261d? | 1999-01-01 A | 1999-12-31 A | 100% | 1999-01-01 | 1999-12-31 | 261d? | start no earlier than 1999-01-01 | S5 | 2088h | 2088h | R99 | Mirko | OAMCM, CM | OAMCM, CM |  |
| 5126 | 1174.4 | OAM Fault Management | 261d? | 1999-01-01 A | 1999-12-31 A | 100% | 1999-01-01 | 1999-12-31 | 261d? | start no earlier than 1999-01-01 | S5 | 2088h | 2088h | R99 | Mirko | OAMFM | OAMFM |  |
| 5127 | 1174.5 | OAM Performance Management | 261d? | 1999-01-01 A | 1999-12-31 A | 100% | 1999-01-01 | 1999-12-31 | 261d? | start no earlier than 1999-01-01 | S5 | 2088h | 2088h | R99 | Mirko | OAMPM, PM | OAMPM, PM |  |
| 5128 | 1175 | Vocabulary | 261d? | 1999-01-01 A | 1999-12-31 A | 100% | 1999-01-01 | 1999-12-31 | 261d? | start no earlier than 1999-01-01 | S1 | 2088h | 2088h | R99 | Alain | Vocabulary | Vocabulary |  |
| 5129 | 1176 | Emergency | 261d? | 1999-01-01 A | 1999-12-31 A | 100% | 1999-01-01 | 1999-12-31 | 261d? | start no earlier than 1999-01-01 | S1 | 2088h | 2088h | R99 | Alain | Emergency | Emergency |  |
| 5130 | 1177 | GSM General Bearer Services (GBS) and interworking scenarios support in UMTS | 261d? | 1999-01-01 A | 1999-12-31 A | 100% | 1999-01-01 | 1999-12-31 | 261d? | start no earlier than 1999-01-01 | S1 | 2088h | 2088h | R99 | Alain | GSM_to_UMTS_Evol | GSM_to_UMTS_Evol |  |
| 5131 | 1178 | GPRS_Mobile_IP_interworking | 261d? | 1999-01-01 A | 1999-12-31 A | 100% | 1999-01-01 | 1999-12-31 | 261d? | start no earlier than 1999-01-01 | N3 | 2088h | 2088h | R99 |  | GPRS_Mobile_IP_interworking | GPRS_Mobile_IP_interworking |  |
| 5132 | 1179 | GSM/UMTS interworking | 261d? | 1999-01-01 A | 1999-12-31 A | 100% | 1999-01-01 | 1999-12-31 | 261d? | start no earlier than 1999-01-01 | N1; N2; N4; R3; S1; SMG | 12528h | 12528h | R99 | Frederic | 2G3Ginterworking | 2G3Ginterworking |  |
| 5133 | 1180 | Handover | 261d? | 1999-01-01 A | 1999-12-31 A | 100% | 1999-01-01 | 1999-12-31 | 261d? | start no earlier than 1999-01-01 | S1; SMG2; N1; N2; N4 | 10440h | 10440h | R99 | Alain | Handover | Handover |  |
| 5134 | 1181 | 2G3Ghandover | 261d? | 1999-01-01 A | 1999-12-31 A | 100% | 1999-01-01 | 1999-12-31 | 261d? | start no earlier than 1999-01-01 | SMG2 | 2088h | 2088h | R99 |  | 2G3Ghandover | 2G3Ghandover |  |
| 5135 | 1182 | Service Provider Name Indication | 261d? | 1999-01-01 A | 1999-12-31 A | 100% | 1999-01-01 | 1999-12-31 | 261d? | start no earlier than 1999-01-01 | S1 | 2088h | 2088h | R99 | Alain | SPANME | SPANME |  |
| 5136 | 1183 | Data & Data_CleanUp | 261d? | 1999-01-01 A | 1999-12-31 A | 100% | 1999-01-01 | 1999-12-31 | 261d? | start no earlier than 1999-01-01 | SMG1 | 2088h | 2088h | R99 |  | Data, Data_CleanUp | Data, Data_CleanUp |  |
| 5137 | 1184 | Unstructured Supplementary Service Data (USSD) | 261d? | 1999-01-01 A | 1999-12-31 A | 100% | 1999-01-01 | 1999-12-31 | 261d? | start no earlier than 1999-01-01 | SMG1; N4 | 4176h | 4176h | R99 | Kimmo | USSD | USSD |  |
| 5138 | 1185 | Man-Machine Interface (MMI) of the User Equipment (UE) | 261d? | 1999-01-01 A | 1999-12-31 A | 100% | 1999-01-01 | 1999-12-31 | 261d? | start no earlier than 1999-01-01 | S1 | 2088h | 2088h | R99 | Alain | MMI | MMI |  |
| 5139 | 1186 | Network Identity and Timezone (NITZ) | 261d? | 1999-01-01 A | 1999-12-31 A | 100% | 1999-01-01 | 1999-12-31 | 261d? | start no earlier than 1999-01-01 | SMG1; SMG3 | 4176h | 4176h | R99 | Alain | NITZ | NITZ |  |
| 5140 | 1187 | Deleted - Operator Determined Barring for Packet Oriented Services | 261d? | 1999-01-01 A | 1999-12-31 A | 100% | 1999-01-01 | 1999-12-31 | 261d? | start no earlier than 1999-01-01 | S1 | 2088h | 2088h | R99 | Alain | ODB_Enh. | ODB_Enh. | SP-69 |
| 5141 | 1188 | Packet Flow Management | 261d? | 1999-01-01 A | 1999-12-31 A | 100% | 1999-01-01 | 1999-12-31 | 261d? | start no earlier than 1999-01-01 | SMG2 | 2088h | 2088h | R99 |  | Packet_Flow_Management | Packet_Flow_Management |  |
| 5142 | 1189 | GPRS_Point-To-Multipoint Group call | 261d? | 1999-01-01 A | 1999-12-31 A | 100% | 1999-01-01 | 1999-12-31 | 261d? | start no earlier than 1999-01-01 | SMG1 | 2088h | 2088h | R99 |  | GPRS_PTMG | GPRS_PTMG |  |

Notes:
- 5119: -
- 5120: - / Impacted TSs and TRs: 22.115, 23.121
- 5121: - / Impacted TSs and TRs: 32.005, 32.015
- 5122: -
- 5123: - / Impacted TSs and TRs: 32.101
- 5124: - / Impacted TSs and TRs: 32.101, 32.102
- 5125: - / Impacted TSs and TRs: 32.106, 32.106-1, 32.106-2, 32.106-3, 32.106-4, 32.106-5, 32.106-6, 32.106-7, 32.106-8
- 5126: - / Impacted TSs and TRs: 32.111, 32.111-1, 32.111-2, 32.111-3, 32.111-4
- 5127: - / Impacted TSs and TRs: 12.04, 32.104
- 5128: - / Impacted TSs and TRs: 21.905
- 5129: - / Impacted TSs and TRs: 22.101
- 5130: UMTS shall support GSM General Bearer Services (GBS) and interworking scenarios as specified in 02.02 / Impacted TSs and TRs: 22.105
- 5131: - / Impacted TSs and TRs: 29.061
- 5132: - / Impacted TSs and TRs: 03.22, 04.18, 04.60, 05.02, 05.08, 05.10, 08.08, 08.18, 08.58, 09.08, 22.011, 23.003, 23.009, 23.014, 23.034, 23.122, 24.007, 24.008, 24.011, 24.080, 29.108
- 5133: - / Impacted TSs and TRs: 04.18, 08.08, 08.58, 22.129, 23.009, 29.002, 29.010
- 5134: - / Impacted TSs and TRs: 04.18, 04.60, 05.02, 05.08, 05.10, 08.08, 29.010
- 5135: Service Provider Name Indication included in R98 (02.07) was not carried into R99 (22.101), but is in the SIM/USIM specification for R99 / Impacted TSs and TRs: 22.101
- 5136: - / Impacted TSs and TRs: 02.01, 02.02, 02.04, 02.34
- 5137: No additional features for R99. / Impacted TSs and TRs: 02.04, 02.90, 23.090, 29.002
- 5138: Data services streamlining + Support for Anonymous Call Rejection / Impacted TSs and TRs: 22.030
- 5139: - / Impacted TSs and TRs: 02.42, 04.08
- 5140: Remove ODB for Packet Oriented Services from R99 / Impacted TSs and TRs: 22.041
- 5141: - / Impacted TSs and TRs: 08.18
- 5142: - / Impacted TSs and TRs: 02.60

| ID | WBS | Task | Duration | Start | Finish | Complete | Baseline start | Baseline finish | Baseline duration | Constraint | Resources | Work | Actual work | Release | MCC resp | Acronym | Acronym_3GU_Export |
| --- | --- | --- | --- | --- | --- | --- | --- | --- | --- | --- | --- | --- | --- | --- | --- | --- | --- |
| 5143 | 1190 | **Call Forwarding** | 261d? | 1999-01-01 A | 1999-12-31 A | 100% | 1999-01-01 | 1999-12-31 | 261d? |  | SMG1; N2; N4 | 16704h | 16704h | R99 | Kimmo |  |  |
| 5144 | 1190.1 | Call Forwarding enhancements | 261d? | 1999-01-01 A | 1999-12-31 A | 100% | 1999-01-01 | 1999-12-31 | 261d? | start no earlier than 1999-01-01 | N4; N2 | 4176h | 4176h | R99 | Kimmo | CF_enhancements | CF_enhancements |
| 5145 | 1190.2 | Call_Forwarding | 261d? | 1999-01-01 A | 1999-12-31 A | 100% | 1999-01-01 | 1999-12-31 | 261d? | start no earlier than 1999-01-01 | SMG1; N2 | 4176h | 4176h | R99 | Kimmo | Call_Forwarding | Call_Forwarding |
| 5146 | 1190.3 | Call_Forwarding_Enhancements | 261d? | 1999-01-01 A | 1999-12-31 A | 100% | 1999-01-01 | 1999-12-31 | 261d? | start no earlier than 1999-01-01 | N4 | 2088h | 2088h | R99 | Kimmo | Call_Forwarding_Enhancements | Call_Forwarding_Enhancements |
| 5147 | 1191 | **Quality of Service** | 261d? | 1999-01-01 A | 1999-12-31 A | 100% | 1999-01-01 | 1999-12-31 | 261d? |  | S2; T2; N1; N2; N4 | 31320h | 31320h | R99 | Maurice |  |  |
| 5148 | 1191.1 | End-to-end UMTS Quality of Service management | 261d? | 1999-01-01 A | 1999-12-31 A | 100% | 1999-01-01 | 1999-12-31 | 261d? | start no earlier than 1999-01-01 | S2; T2; N1; N2; N4 | 10440h | 10440h | R99 | Maurice | QoS | QoS |
| 5149 | 1191.2 | End-to-end QoS for PS Domain including IMS | 261d? | 1999-01-01 A | 1999-12-31 A | 100% | 1999-01-01 | 1999-12-31 | 261d? | start no earlier than 1999-01-01 | S2 | 2088h | 2088h | R99 | Maurice | E2EQoS99 | E2EQoS |
| 5150 | 1191.3 | GPRS-enhanced_QoS | 261d? | 1999-01-01 A | 1999-12-31 A | 100% | 1999-01-01 | 1999-12-31 | 261d? | start no earlier than 1999-01-01 | T2 | 2088h | 2088h | R99 |  | GPRS-enhanced_QoS | GPRS-enhanced_QoS |
| 5151 | 1191.4 | QoS_enhancements | 261d? | 1999-01-01 A | 1999-12-31 A | 100% | 1999-01-01 | 1999-12-31 | 261d? | start no earlier than 1999-01-01 | N2; N1; N4 | 6264h | 6264h | R99 | Kimmo | QoS_enhancements | QoS_enhancements |
| 5152 | 1192 | Support of Localised Service Area | 261d? | 1999-01-01 A | 1999-12-31 A | 100% | 1999-01-01 | 1999-12-31 | 261d? | start no earlier than 1999-01-01 | SMG2; SMG3; SMG7; N2 | 8352h | 8352h | R99 | Maurice | SoLSA | SoLSA |
| 5153 | 1193 | Transcoder_location | 261d? | 1999-01-01 A | 1999-12-31 A | 100% | 1999-01-01 | 1999-12-31 | 261d? | start no earlier than 1999-01-01 | S2 | 2088h | 2088h | R99 | Maurice | Transcoder_location | Transcoder_location |
| 5154 | 1194 | Antenna_test_methods | 261d? | 1999-01-01 A | 1999-12-31 A | 100% | 1999-01-01 | 1999-12-31 | 261d? | start no earlier than 1999-01-01 | SMG2 | 2088h | 2088h | R99 |  | Antenna_test_methods | Antenna_test_methods |
| 5155 | 1195 | WBAMR / high quality speech in UMTS Phase 1 but not in R99 | 261d? | 1999-01-01 A | 1999-12-31 A | 100% | 1999-01-01 | 1999-12-31 | 261d? | start no earlier than 1999-01-01 | S1 | 2088h | 2088h | R99 | Alain | WBAMR | WBAMR |
| 5156 | 1196 | **Codec** | 261d? | 1999-01-01 A | 1999-12-31 A | 100% | 1999-01-01 | 1999-12-31 | 261d? |  | S4 | 27144h | 27144h | R99 | Paolo |  |  |
| 5157 | 1196.1 | **Codecs for Multimedia Telephony Service** | 261d? | 1999-01-01 A | 1999-12-31 A | 100% | 1999-01-01 | 1999-12-31 | 261d? |  | S4 | 14616h | 14616h | R99 | Paolo | Codec_for_Multimedia_Telephony | Codec_for_Multimedia_Telephony |
| 5158 | 1196.1.1 | Codecs for Multimedia Telephony Service | 261d? | 1999-01-01 A | 1999-12-31 A | 100% | 1999-01-01 | 1999-12-31 | 261d? | start no earlier than 1999-01-01 | S4 | 2088h | 2088h | R99 | Paolo | Multimedia_Codec | Multimedia_Codec |
| 5159 | 1196.1.2 | Codecs for Multimedia Telephony Service | 261d? | 1999-01-01 A | 1999-12-31 A | 100% | 1999-01-01 | 1999-12-31 | 261d? | start no earlier than 1999-01-01 | S4 | 2088h | 2088h | R99 | Paolo | CSM | CSM |
| 5160 | 1196.1.3 | Codecs for Multimedia Telephony Service | 261d? | 1999-01-01 A | 1999-12-31 A | 100% | 1999-01-01 | 1999-12-31 | 261d? | start no earlier than 1999-01-01 | S4 | 2088h | 2088h | R99 | Paolo | WI2MMC | WI2MMC |
| 5161 | 1196.1.4 | Codecs for Multimedia Telephony Service | 261d? | 1999-01-01 A | 1999-12-31 A | 100% | 1999-01-01 | 1999-12-31 | 261d? | start no earlier than 1999-01-01 | S4 | 2088h | 2088h | R99 | Paolo | Codec(s)_for_CS_MM_Tel._Serv | Codec(s)_for_CS_MM_Tel._Serv |
| 5162 | 1196.1.5 | Codecs for Multimedia Telephony Service | 261d? | 1999-01-01 A | 1999-12-31 A | 100% | 1999-01-01 | 1999-12-31 | 261d? | start no earlier than 1999-01-01 | S4 | 2088h | 2088h | R99 | Paolo | Codec(s)_for_MM_Tel_Service | Codec(s)_for_MM_Tel_Service |
| 5163 | 1196.1.6 | Codecs for Multimedia Telephony Service | 261d? | 1999-01-01 A | 1999-12-31 A | 100% | 1999-01-01 | 1999-12-31 | 261d? | start no earlier than 1999-01-01 | S4 | 2088h | 2088h | R99 | Paolo |  |  |
| 5164 | 1196.2 | QoS for Speech and Multimedia Codec | 261d? | 1999-01-01 A | 1999-12-31 A | 100% | 1999-01-01 | 1999-12-31 | 261d? | start no earlier than 1999-01-01 | S4 | 2088h | 2088h | R99 | Paolo | QoS_for_Speech_&_MM_Codecs_/_AMR | QoS_for_Speech_&_MM_Codecs_/_AMR |
| 5165 | 1196.3 | Tandem Free Operation - Adaptive Multi-Rate codec types | 261d? | 1999-01-01 A | 1999-12-31 A | 100% | 1999-01-01 | 1999-12-31 | 261d? | start no earlier than 1999-01-01 | S4 | 2088h | 2088h | R99 | Paolo | TFOAMR | TFOAMR |
| 5166 | 1196.4 | Noise Suppression for AMR | 261d? | 1999-01-01 A | 1999-12-31 A | 100% | 1999-01-01 | 1999-12-31 | 261d? | start no earlier than 1999-01-01 | S4 | 2088h | 2088h | R99 | Paolo | AMRNS | AMRNS |
| 5167 | 1196.5 | Out-of-Band Transcoder | 261d? | 1999-01-01 A | 1999-12-31 A | 100% | 1999-01-01 | 1999-12-31 | 261d? | start no earlier than 1999-01-01 | N1 | 2088h | 2088h | R99 | Frederic | OoBT | OoBT |
| 5168 | 1196.6 | Out-of-Band Transcoder Control | 261d? | 1999-01-01 A | 1999-12-31 A | 100% | 1999-01-01 | 1999-12-31 | 261d? | start no earlier than 1999-01-01 | N1 | 2088h | 2088h | R99 | Frederic | OoBTC | OoBTC |
| 5169 | 1197 | Advanced Speech Call Items enhancements | 261d? | 1999-01-01 A | 1999-12-31 A | 100% | 1999-01-01 | 1999-12-31 | 261d? | start no earlier than 1999-01-01 | SMG1; SMG2; SMG3; SMG7; SMG9; N1; N4; S1; T2 | 18792h | 18792h | R99 | Alain | ASCI | ASCI |
| 5170 | 1198 | Call Control improvements | 261d? | 1999-01-01 A | 1999-12-31 A | 100% | 1999-01-01 | 1999-12-31 | 261d? | start no earlier than 1999-01-01 | N1 | 2088h | 2088h | R99 | Frederic | CC_Related_items | CC_Related_items |
| 5171 | 1199 | Multimedia | 261d? | 1999-01-01 A | 1999-12-31 A | 100% | 1999-01-01 | 1999-12-31 | 261d? | start no earlier than 1999-01-01 | N1; N3 | 4176h | 4176h | R99 | Frederic | Multimedia | Multimedia |
| 5172 | 1200 | Sub-System Number allocation for RANAP, RNSAP | 261d? | 1999-01-01 A | 1999-12-31 A | 100% | 1999-01-01 | 1999-12-31 | 261d? | start no earlier than 1999-01-01 | N2 | 2088h | 2088h | R99 | Frederic | SSN_allocation | SSN_allocation |
| 5173 | 1201 | Intranet / ISP access with DHCP end-to-end | 261d? | 1999-01-01 A | 1999-12-31 A | 100% | 1999-01-01 | 1999-12-31 | 261d? | start no earlier than 1999-01-01 | N3 | 2088h | 2088h | R99 | Gwiho | ISPaccess | ISPaccess |
| 5174 | 1202 | Point_to_Multipoint_Services | 261d? | 1999-01-01 A | 1999-12-31 A | 100% | 1999-01-01 | 1999-12-31 | 261d? | start no earlier than 1999-01-01 | N3 | 2088h | 2088h | R99 | Gwiho | Point_to_Multipoint_Services | Point_to_Multipoint_Services |
| 5175 | 1203 | Facsimile | 261d? | 1999-01-01 A | 1999-12-31 A | 100% | 1999-01-01 | 1999-12-31 | 261d? | start no earlier than 1999-01-01 | S1 | 2088h | 2088h | R99 | Alain | FAX | FAX |
| 5176 | 1204 | Realtime_NT_FAX_in_UMTS | 261d? | 1999-01-01 A | 1999-12-31 A | 100% | 1999-01-01 | 1999-12-31 | 261d? | start no earlier than 1999-01-01 | N3 | 2088h | 2088h | R99 | Gwiho | Realtime_NT_FAX_in_UMTS | Realtime_NT_FAX_in_UMTS |
| 5177 | 1205 | Gateway Location Register (GLR) - Mobile Application Part (MAP) specification | 261d? | 1999-01-01 A | 1999-12-31 A | 100% | 1999-01-01 | 1999-12-31 | 261d? | start no earlier than 1999-01-01 | N4 | 2088h | 2088h | R99 | Kimmo | GLR | GLR |
| 5178 | 1206 | Multiple Subscriber Profile phase 2 | 261d? | 1999-01-01 A | 1999-12-31 A | 100% | 1999-01-01 | 1999-12-31 | 261d? | start no earlier than 1999-01-01 | S1; N4 | 4176h | 4176h | R99 | Alain | MSP2 | MSP2 |
| 5179 | 1207 | Prepaging | 261d? | 1999-01-01 A | 1999-12-31 A | 100% | 1999-01-01 | 1999-12-31 | 261d? | start no earlier than 1999-01-01 | N2; N4 | 4176h | 4176h | R99 | Kimmo | Prepaging | Prepaging |
| 5180 | 1208 | Re-definition of channel quality measure used for AMR link adaptation for Downlink Advanced Receiver Performance (DARP) MS | 261d? | 1999-01-01 A | 1999-12-31 A | 100% | 1999-01-01 | 1999-12-31 | 261d? | start no earlier than 1999-01-01 | SMG | 2088h | 2088h | R99 |  |  |  |
| 5181 | 1209 | Harmonized Standard | 261d? | 1999-01-01 A | 1999-12-31 A | 100% | 1999-01-01 | 1999-12-31 | 261d? | start no earlier than 1999-01-01 | SMG2 | 2088h | 2088h | R99 |  | HS | HS |
| 5182 | 1210 | Streamlining of specifications | 261d? | 1999-01-01 A | 1999-12-31 A | 100% | 1999-01-01 | 1999-12-31 | 261d? | start no earlier than 1999-01-01 | N3 | 2088h | 2088h | R99 | Gwiho | Streamlining | Streamlining |
| 5183 | 1211 | R99_Service_Clean_up | 261d? | 1999-01-01 A | 1999-12-31 A | 100% | 1999-01-01 | 1999-12-31 | 261d? | start no earlier than 1999-01-01 | N3 | 2088h | 2088h | R99 | Gwiho | R99_Service_Clean_up | R99_Service_Clean_up |

Notes:
- 5143: -
- 5144: No additional features for R99. / Impacted TSs and TRs: 23.078, 23.079, 23.082, 29.002, 29.078
- 5145: - / Impacted TSs and TRs: 02.82, 29.002
- 5146: - / Impacted TSs and TRs: 23.082
- 5147: WID SMG 98-0781 End To End UMTS QoS Management
- 5148: WID SMG 98-0781 End To End UMTS QoS Management / Impacted TSs and TRs: 23.107, 23.907, 24.008
- 5149: Acronym changed from E2EQos / Impacted TSs and TRs: 23.060, 23.170
- 5150: AT-commands for Enhanced QoS Support management / Impacted TSs and TRs: 27.007
- 5151: - / Impacted TSs and TRs: 23.008, 23.016, 24.008, 29.002, 29.060
- 5152: Mechanism which can be used as a platform for providing special tariffs and/or special set of service features for certain subscribers within a regionally restricted area or areas. No additional features for R99. / Impacted TSs and TRs: 04.08, 04.18, 08.08, 11.10-1, 29.002
- 5153: UE location identification: background information and associated primitives 2. Transcoder location at the core network and source depending coding belonging to the non-access stratum. / Impacted TSs and TRs: 23.110
- 5154: - / Impacted TSs and TRs: 03.30
- 5155: Add requirement for high quality speech in UMTS Phase 1 but not in R99 / Impacted TSs and TRs: 22.105
- 5156: -
- 5157: -
- 5158: - / Impacted TSs and TRs: 26.911, 26.104, 26.111
- 5159: - / Impacted TSs and TRs: 26.911, 26.104, 26.111
- 5160: - / Impacted TSs and TRs: 26.911, 26.104, 26.111
- 5161: - / Impacted TSs and TRs: 26.911, 26.104, 26.111
- 5162: - / Impacted TSs and TRs: 26.911, 26.104, 26.111
- 5163: - / Impacted TSs and TRs: 26.911, 26.104, 26.111
- 5164: - / Impacted TSs and TRs: 26.102, 26.912
- 5165: UMTS_AMR2 is default Codec Type in R99 dual_mode terminals / Impacted TSs and TRs: 26.103
- 5166: Combination of the AMR speech codec and the Noise Suppression function. TS 06.77 and TR 06.78 only apply to GSM. They apply to UMTS from Rel-4 onwards, when they were converted to TS 26.077 and TR 26.078. / Impacted TSs and TRs: 06.77, 06.78
- 5167: Transcoder handling in the CN at inter-system handover and relocation + Introduction of UMTS AMR / Impacted TSs and TRs: 23.009, 24.008
- 5168: 24.008 CR#0572 in NP-020220 was approved under this WI / Impacted TSs and TRs: 24.008 CR#0572 in NP-020220
- 5169: - / Impacted TSs and TRs: 02.30, 02.68, 03.68, 03.69, 04.18, 08.08, 11.10-1, 11.11, 23.067, 23.094, 24.008, 24.067, 27.007, 29.002
- 5170: Minor improvements to 24.007 and 24.008 to increase the number of simultaneous calls/sessions from the present 7: the TI value is increased (NP-99441). / Impacted TSs and TRs: 24.007, 24.008
- 5171: - / Impacted TSs and TRs: 24.008, 27.001, 29.007
- 5172: Sub-System Number allocation for Radio Access Network Application Part, Radio Network Subsystem Application Part / Impacted TSs and TRs: 23.003
- 5173: Access to an Intranet/ISP with DHCP end to end / Impacted TSs and TRs: 29.061
- 5174: Support for the IP-Multicast protocol / Impacted TSs and TRs: 29.061
- 5175: - / Impacted TSs and TRs: 22.003, 22.100
- 5176: Asynchronous Interface for real-time NT Fax + Introduction of Asynchronous interface for Real-time non-transparent FAX / Impacted TSs and TRs: 27.001, 27.003
- 5177: - / Impacted TSs and TRs: 29.120
- 5178: - / Impacted TSs and TRs: 22.097, 23.072, 23.083, 23.084, 23.091, 23.093, 23.097
- 5179: - / Impacted TSs and TRs: 23.018, 23.082, 29.002
- 5180: Re-definition of channel quality measure used for AMR link adaptation for DARP MS / Impacted TSs and TRs: 05.09
- 5181: - / Impacted TSs and TRs: 13.21
- 5182: - / Impacted TSs and TRs: 27.060, 29.061
- 5183: - / Impacted TSs and TRs: 03.10, 27.001, 27.002, 27.003, 27.060, 29.007, 29.061

| ID | WBS | Task | Type | Duration | Start | Finish | Complete | Baseline start | Baseline finish | Baseline duration | Constraint | Resources | Work | Actual work | Acronym | Release | MCC resp | Acronym_3GU_Export | Impacted TSs and TRs | TSG stopped | WI rapporteur name | WI rapporteur e-mail |
| --- | --- | --- | --- | --- | --- | --- | --- | --- | --- | --- | --- | --- | --- | --- | --- | --- | --- | --- | --- | --- | --- | --- |
| 5184 | 1212 | **(Small) Technical Enhancements and Improvements for R99** |  | 261d? | 1999-01-01 A | 1999-12-31 A | 100% | 1999-01-01 | 1999-12-31 | 261d? |  | N3 | 6264h | 6264h | TEI | R99 | Gwiho | TEI |  |  |  |  |
| 5185 | 1212.1 | TEI_[CS_Data] |  | 261d? | 1999-01-01 A | 1999-12-31 A | 100% | 1999-01-01 | 1999-12-31 | 261d? | start no earlier than 1999-01-01 | N3 | 2088h | 2088h | TEI_[CS_Data] | R99 | Gwiho | TEI_[CS_Data] |  |  |  |  |
| 5186 | 1212.2 | TEI_[GPRS] |  | 261d? | 1999-01-01 A | 1999-12-31 A | 100% | 1999-01-01 | 1999-12-31 | 261d? | start no earlier than 1999-01-01 | N3 | 2088h | 2088h | TEI_[GPRS] | R99 | Gwiho | TEI_[GPRS] |  |  |  |  |
| 5187 | 1213 | **R99 UE Conformance Testing** |  | 261d? | 1999-01-01 A | 1999-12-31 A | 100% | 1999-01-01 | 1999-12-31 | 261d? |  | R5; T1 | 6264h | 6264h | TEI_Test | R99 | Ingbert | TEI_Test | 34.108, 34.121, 34.122, 34.123-1, 34.123-2, 34.123-3 |  |  |  |
| 5188 | 1213.1 | Deleted - RTEI |  | 261d? | 1999-01-01 A | 1999-12-31 A | 100% | 1999-01-01 | 1999-12-31 | 261d? | start no earlier than 1999-01-01 | T1 | 2088h | 2088h | RTEI | R99 | Ingbert | RTEI | 34.123-1 CR#0650, 0651, 34.123-3 CR#0148, 0149, 0150 | TP-06 |  |  |
| 5189 | 1213.2 | Common test environments for User Equipment (UE); Conformance testing | milestone | 0d? | 1999-01-01 A | 1999-01-01 A | 100% | 1999-01-01 | 1999-01-01 | 0d? | start no earlier than 1999-01-01 | R5; T1 |  |  |  | R99 | Ingbert |  | 34.108 |  |  |  |
| 5190 | 1213.3 | Terminal conformance specification, Radio transmission and reception (FDD) | milestone | 0d? | 1999-01-01 A | 1999-01-01 A | 100% | 1999-01-01 | 1999-01-01 | 0d? | start no earlier than 1999-01-01 | R5; T1 |  |  |  | R99 | Ingbert |  | 34.121 |  |  |  |
| 5191 | 1213.4 | Terminal conformance specification, Radio transmission and reception (TDD) | milestone | 0d? | 1999-01-01 A | 1999-01-01 A | 100% | 1999-01-01 | 1999-01-01 | 0d? | start no earlier than 1999-01-01 | R5; T1 |  |  |  | R99 | Ingbert |  | 34.122 |  |  |  |
| 5192 | 1213.5 | UE conformance specification; Part 1: Protocol conformance specification | milestone | 0d? | 1999-01-01 A | 1999-01-01 A | 100% | 1999-01-01 | 1999-01-01 | 0d? | start no earlier than 1999-01-01 | R5; T1 |  |  |  | R99 | Ingbert |  | 34.123-1 |  |  |  |
| 5193 | 1213.6 | UE conformance specification; Part 2: Implementation Conformance Statement (ICS) specification | milestone | 0d? | 1999-01-01 A | 1999-01-01 A | 100% | 1999-01-01 | 1999-01-01 | 0d? | start no earlier than 1999-01-01 | R5; T1 |  |  |  | R99 | Ingbert |  | 34.123-2 |  |  |  |
| 5194 | 1213.7 | UE conformance specification; Part 3: Abstract test suites (ATSs) | milestone | 0d? | 1999-01-01 A | 1999-01-01 A | 100% | 1999-01-01 | 1999-01-01 | 0d? | start no earlier than 1999-01-01 | R5; T1 |  |  |  | R99 | Ingbert |  | 34.123-3 |  |  |  |
| 5195 | 1214 | Deleted - Dual Tone Multi-Frequency signalling : Support in the whole 3GPP system |  | 261d? | 1999-01-01 A | 1999-12-31 A | 100% | 1999-01-01 | 1999-12-31 | 261d? | start no earlier than 1999-01-01 | N1 | 2088h | 2088h | DTMF | R99 | Frederic | DTMF | 23.014 CR#0004 | NP-06 |  |  |
| 5196 | 1215 | Deleted - Intersystem_Change |  | 261d? | 1999-01-01 A | 1999-12-31 A | 100% | 1999-01-01 | 1999-12-31 | 261d? | start no earlier than 1999-01-01 | SMG | 2088h | 2088h | Intersystem_Change | R99 |  | Intersystem_Change | 04.18 CR#A243 | SMG |  |  |
| 5197 | 1216 | Deleted - Long_Forwardedto_Numbers |  | 261d? | 1999-01-01 A | 1999-12-31 A | 100% | 1999-01-01 | 1999-12-31 | 261d? | start no earlier than 1999-01-01 | N2 | 2088h | 2088h | Long_Forwardedto_Numbers | R99 | Kimmo | Long_Forwardedto_Numbers | 29.002 | NP-06 |  |  |
| 5198 | 1217 | Deleted - RANimp-FSEarlyUE |  | 261d? | 1999-01-01 A | 1999-12-31 A | 100% | 1999-01-01 | 1999-12-31 | 261d? | start no earlier than 1999-01-01 | R3 | 2088h | 2088h | RANimp-FSEarlyUE | R99 | Juha | RANimp-FSEarlyUE | 25.413 CR#0520, 0538, 0565, 0563, 0541, 0540, 0539, 0547 | RP-06 |  |  |
| 5199 | 1218 | Release 1999 Studies |  | 261d? | 1999-01-01 A | 1999-12-31 A | 100% | 1999-01-01 | 1999-12-31 | 261d? |  | S1; T2 | 4176h | 4176h |  | R99 | Alain |  |  |  |  |  |
| 5200 | 1219 | Advanced Addressing/Numbering |  | 261d? | 1999-01-01 A | 1999-12-31 A | 100% | 1999-01-01 | 1999-12-31 | 261d? | start no earlier than 1999-01-01 | S1 | 2088h | 2088h | Numbering | R99 | Alain | Numbering | 22.975 |  | Vodafone | mona.mustapha@vodafone.com |
| 5201 | 1220 | Combined GSM and Mobile IP mobility handling in UMTS IP CN |  | 261d? | 1999-01-01 A | 1999-12-31 A | 100% | 1999-01-01 | 1999-12-31 | 261d? | start no earlier than 1999-01-01 | S2 | 2088h | 2088h |  | R99 | Maurice |  | 23.923 |  |  |  |
| 5202 | 1221 | UE Capabilities Requirements |  | 261d? | 1999-01-01 A | 1999-12-31 A | 100% | 1999-01-01 | 1999-12-31 | 261d? | start no earlier than 1999-01-01 | T2 | 2088h | 2088h | UCR | R99 |  | UCR | 21.904 |  |  |  |
| 5203 | 1222 | Electrical safety requirements and regulations |  | 261d? | 1999-01-01 A | 1999-12-31 A | 100% | 1999-01-01 | 1999-12-31 | 261d? | start no earlier than 1999-01-01 | T2 | 2088h | 2088h |  | R99 |  |  | 34.907 |  |  |  |
| 5204 | 1223 | Specific Absorbtion Rate (SAR) requirements and regulations in different regions |  | 261d? | 1999-01-01 A | 1999-12-31 A | 100% | 1999-01-01 | 1999-12-31 | 261d? | start no earlier than 1999-01-01 | T2 | 2088h | 2088h |  | R99 |  |  | 34.925 |  |  |  |
| 5205 | 1224 | Multi-mode UE issues |  | 261d? | 1999-01-01 A | 1999-12-31 A | 100% | 1999-01-01 | 1999-12-31 | 261d? | start no earlier than 1999-01-01 | T2 | 2088h | 2088h |  | R99 |  |  | 21.810, 21.910 |  |  |  |
| 5206 | 1225 | Provision of fax service in GSM and UMTS |  | 261d? | 1999-01-01 A | 1999-12-31 A | 100% | 1999-01-01 | 1999-12-31 | 261d? | start no earlier than 1999-01-01 | T2 | 2088h | 2088h |  | R99 |  |  | 22.945 |  | Ericsson | peter.bleckert@ericsson.com |
| 5207 | 1226 | Separating Radio Resources and Mobility Management specific parts of the MS Classmark |  | 261d | 1999-01-01 A | 1999-12-31 A | 100% | 1999-01-01 | 1999-12-31 | 261d |  | T2 | 2088h | 2088h |  | R99 |  |  | 23.814 |  |  |  |

Notes:
- 5184: -
- 5185: -
- 5186: -
- 5187: Specifies Conformance Tests for a 3G UE to be recognised as 3GPP-standard compliant. A 3GPP-external body, GCF (Global Certification Forum), delivers certificates to prove that a UE has correctly passed tests and is then conform to the 3GPP standard.
- 5188: No CR or new TS/TR approved under this WI
- 5189: -
- 5190: measurement procedures for the conformance test of the UE that contain transmitting characteristics, receiving characteristics and performance requirements in addition to requirements for support of RRM (Radio Resource Management) in FDD mode.
- 5191: measurement procedures for the conformance test of the UE that contain transmitting characteristics, receiving characteristics and performance requirements in addition to requirements for support of RRM (Radio Resource Management) in TDD mode.
- 5192: TS 34.123, composed of three parts, actually specifies the protocol conformance testing for the 3G UE. Part 1 describes the overall test structure.
- 5193: Part 2 contains the applicability of each test case defined as the Implementation Conformance Statement (ICS) proforma, in compliance with the relevant requirements, and in accordance with the relevant guidance given in ISO/IEC 9646-7 and ETS 300 406.
- 5194: Part 3 specifies the protocol conformance testing in TTCN for the 3G UE at the Uu interface. It defines the TTCN test specification and design considerations in Abstract Test Suites based on the test cases specified in prose in part 1.
- 5195: No CR or new TS/TR approved under this WI
- 5196: No CR or new TS/TR approved under this WI
- 5197: -
- 5198: No CR or new TS/TR approved under this WI
- 5199: -
- 5200: Study on requirements for numbering and addressing for UMTS
- 5201: -
- 5202: Moved to CT1 at TSG-T closure
- 5203: Moved to RAN4 at TSG-T closure. TR summarizes differences between international and national standards relevant to IEC60950 and refers to regulations for conformity assessment due to different regulatory environments in different countries / regions.
- 5204: Moved to RAN4 at TSG-T closure.
- 5205: Moved to CT1 at TSG-T closure. Consequences on roaming capabilities and service availability (e.g. handover) of multi-mode UEs while roaming in various regions with various network configurations. Case studies for each of the possible scenarios in specs
- 5206: CP#27: Moved to C1 on closure of T2; see TP-050062. CP#28: C1->C3
- 5207: CP#27: change of WG as a result of closure of CN and T.
